# QXFL_v6

Schedule from MS Project, 2012-10-08 to 2019-05-28, costs in $, A marks actual dates.
Fermi National Accelerator Laboratory

## Calendars

- Standard: Mon-Fri 08:00-12:00, 13:00-17:00; Sat-Sun off. Exceptions (off unless hours are given): 2013-12-24 to 2023-12-24 (Xmas Eve, recurring), 2013-12-31 to 2022-12-27 (NYE, recurring), 2014-01-01 to 2023-01-04 (NYD, recurring), 2014-01-20 to 2023-01-16 (MLK, recurring), 2014-05-26 to 2023-05-26 (Memorial, recurring), 2014-07-04 to 2023-07-07 (Independence, recurring), 2014-09-01 to 2023-09-04 (Labor, recurring), 2014-11-27 to 2023-11-23 (Thanksgiving, recurring), 2014-11-28 to 2023-11-24 (Day after Thanksgiving, recurring), 2014-12-25 to 2022-12-25 (Xmas, recurring).

## Resources

| Resource | Rate |
| --- | --- |
| Engineer (Sr) - F | 182.58 |
| Engineer (Jr) - F | 165.91 |
| Designer - F | 107.38 |
| Drafter - F | 63.12 |
| Technician Supervisor - F | 126.83 |
| Technician - F | 77.46 |
| QC - F | 102.02 |
| QA - F | 155.51 |
| Scientist - F | 159.94 |
| Engineer (Sr) - B | 157.32 |
| Lead Design Eng - B | 187.96 |
| Drafter - B | 112.27 |
| Technician Supervisor - B | 146.93 |
| Technician - B | 116.64 |
| QC - B | 116.64 |
| QA - B | 142.39 |
| Scientist - B | 197.57 |
| Engineer - L | 187.1 |
| Designer - L | 142.12 |
| EngAsst - L | 142.12 |
| Technician - L | 112 |
| Scientist - L | 187.1 |

## Schedule

| ID | WBS | Task | Type | Duration | Start | Finish | Predecessors | Complete | Constraint |
| --- | --- | --- | --- | --- | --- | --- | --- | --- | --- |
| 1 | 1 | **Conceptual design** |  | 212d | 2012-10-08 A | 2013-07-31 A |  | 100% |  |
| 2 | 1.1 | Conceptual design |  | 38w | 2012-10-08 A | 2013-06-28 A |  | 100% | finish no earlier than 2013-06-28 |
| 3 | 1.2 | Coil ID and OD selection | milestone | 0d | 2013-03-01 A | 2013-03-01 A |  | 100% | start no earlier than 2013-03-01 |
| 4 | 1.3 | Cable design decision | milestone | 0d | 2013-05-31 A | 2013-05-31 A |  | 100% | start no earlier than 2013-05-31 |
| 5 | 1.4 | Internal Coil Design WG OK | milestone | 0d | 2013-06-28 A | 2013-06-28 A | 2, 4 | 100% |  |
| 6 | 1.5 | Internal Structure Design WG OK | milestone | 0d | 2013-07-31 A | 2013-07-31 A |  | 100% | start no earlier than 2013-07-31 |
| 7 | 2 | **QXF Curing Molds design (Short and Long)** |  | 45d | 2013-03-01 A | 2013-05-02 A | 3 | 100% |  |
| 8 | 2.1 | Mold Design |  | 20d | 2013-03-01 A | 2013-03-28 A |  | 100% |  |
| 9 | 2.2 | Laminations Design & Draft |  | 10d | 2013-03-29 A | 2013-04-11 A | 8 | 100% |  |
| 10 | 2.3 | Mold other tooling D&D |  | 15d | 2013-04-12 A | 2013-05-02 A | 9 | 100% |  |
| 11 | 3 | **Short mold** |  | 132d | 2013-04-12 A | 2013-10-14 A |  | 100% |  |
| 12 | 3.1 | Laminations procurement for short mold |  | 100d | 2013-04-12 A | 2013-08-29 A | 9 | 100% |  |
| 13 | 3.2 | QA & assembly -details in Miao schedule |  | 32d | 2013-08-30 A | 2013-10-14 A | 12 | 100% |  |
| 14 | 4 | **Long mold** |  | 132d | 2014-07-01 A | 2015-01-12 A |  | 100% |  |
| 15 | 4.1 | Laminations procurement for long mold |  | 50d | 2014-07-01 A | 2014-09-10 A |  | 100% | start no earlier than 2014-07-01 |
| 16 | 4.2 | duration of short * 1.5 |  | 45d | 2014-10-06 A | 2015-01-12 A |  | 100% | start no earlier than 2014-10-05 |
| 17 | 5 | **Coil Parts by rapid prototyping** |  | 50d | 2013-07-01 A | 2013-09-06 A |  | 100% |  |
| 18 | 5.1 | model and drawings |  | 50d | 2013-07-01 A | 2013-09-06 A | 5 | 100% |  |
| 19 | 6 | **Coil Parts** |  | 194d | 2013-07-01 A | 2014-04-02 A | 5 | 100% |  |
| 20 | 6.1 | Design and Draft |  | 45d | 2013-07-01 A | 2013-08-30 A |  | 100% |  |
| 21 | 6.2 | **Wedge Procurement** |  | 128d | 2013-10-01 A | 2014-04-02 A | 20 | 100% |  |
| 22 | 6.2.1 | Wedge samples |  | 68d | 2013-10-01 A | 2014-01-07 A |  | 100% | start no earlier than 2013-10-01 |
| 23 | 6.2.2 | Wedges for 1st 2 coils |  | 10d | 2014-01-08 A | 2014-01-22 A | 22 | 100% |  |
| 24 | 6.2.3 | Wedges for L1 all coils |  | 45d | 2014-01-08 A | 2014-03-12 A | 22 | 100% |  |
| 25 | 6.2.4 | Wedges for L2 all coils |  | 60d | 2014-01-08 A | 2014-04-02 A | 22 | 100% |  |
| 26 | 6.3 | Coil Parts Procurement |  | 80d | 2013-09-02 A | 2013-12-20 A | 20 | 100% |  |
| 27 | 6.4 | Inspection |  | 20d | 2013-12-23 A | 2014-01-23 A | 26 | 100% |  |
| 28 | 6.5 | Plasma Coating |  | 10d | 2014-01-24 A | 2014-02-06 A | 27 | 100% |  |
| 29 | 6.6 | Thickness measurement |  | 2d | 2014-02-07 A | 2014-02-10 A | 28 | 100% |  |

| ID | WBS | Task | Type | Duration | Start | Finish | Predecessors | Complete | Constraint | Resources | Work | Actual work | Cost | Actual cost |
| --- | --- | --- | --- | --- | --- | --- | --- | --- | --- | --- | --- | --- | --- | --- |
| 30 | 7 | **Protection Heaters & Instrumentation** |  | 213d | 2013-09-30 A | 2014-07-31 A | 5 | 100% |  |  |  |  |  |  |
| 31 | 7.1 | Concept |  | 33d | 2013-09-30 A | 2013-11-13 A | 5 | 100% | start no earlier than 2013-09-29 |  |  |  |  |  |
| 32 | 7.2 | Design |  | 60d | 2013-11-14 A | 2014-02-11 A | 31, 20 | 100% |  |  |  |  |  |  |
| 33 | 7.3 | feedback from PC coils |  | 40d | 2014-02-12 A | 2014-04-08 A | 32, 51 | 100% |  |  |  |  |  |  |
| 34 | 7.4 | procure sets for first coils |  | 30d | 2014-04-09 A | 2014-05-20 A | 33 | 100% |  |  |  |  |  |  |
| 35 | 7.5 | Procure final sets |  | 50d | 2014-05-21 A | 2014-07-31 A | 34 | 100% | start no earlier than 2014-04-20 |  |  |  |  |  |
| 36 | 8 | **Winding and Curing Tooling** |  | 459d | 2013-03-01 A | 2014-12-16 A |  | 100% |  |  |  |  |  |  |
| 37 | 8.1 | Winding Mandrel Design and Draft |  | 35d | 2013-03-01 A | 2013-04-18 A | 3 | 100% |  |  |  |  |  |  |
| 38 | 8.2 | **SQXF W&C** |  | 125d | 2013-04-19 A | 2013-10-10 A | 37 | 100% |  |  |  |  |  |  |
| 39 | 8.2.1 | Winding Tooling Procurement |  | 65d | 2013-04-19 A | 2013-07-18 A |  | 100% |  |  |  |  |  |  |
| 40 | 8.2.2 | QA & Assembly |  | 15d | 2013-07-19 A | 2013-08-08 A | 39 | 100% |  |  |  |  |  |  |
| 41 | 8.2.3 | Other tooling D&D |  | 25d | 2013-05-31 A | 2013-07-04 A | 4 | 100% |  |  |  |  |  |  |
| 42 | 8.2.4 | other tooling procur |  | 65d | 2013-07-05 A | 2013-10-03 A | 41 | 100% |  |  |  |  |  |  |
| 43 | 8.2.5 | Other tooling QA |  | 5d | 2013-10-04 A | 2013-10-10 A | 42 | 100% |  |  |  |  |  |  |
| 44 | 8.3 | **LQXF W&C tooling** |  | 172d | 2014-04-14 A | 2014-12-16 A | 37 | 100% |  |  |  |  |  |  |
| 45 | 8.3.1 | procurement, QC and instal |  | 125d | 2014-04-14 A | 2014-12-16 A |  | 100% | start no earlier than 2014-04-13 |  |  |  |  |  |
| 46 | 9 | **Reaction & Potting Tooling** |  | 629d | 2013-03-01 A | 2015-08-20 A | 3 | 100% |  |  |  |  |  |  |
| 47 | 9.1 | design |  | 5.5mo | 2013-03-01 A | 2013-08-01 A |  | 100% |  |  |  |  |  |  |
| 48 | 9.2 | QXFS procurement & QC |  | 7.5mo | 2013-11-18 A | 2014-06-20 A | 47 | 100% | start no earlier than 2013-11-17 |  |  |  |  |  |
| 49 | 9.3 | QXFP procurement & QC |  | 12mo | 2014-06-30 A | 2015-08-20 A | 47 | 100% | start no earlier than 2014-06-29 |  |  |  |  |  |
| 50 | 10 | **Handling & Shipping Tooling** |  | 135d | 2013-08-19 A | 2014-02-27 A |  | 100% |  |  |  |  |  |  |
| 51 | 10.1 | design |  | 45d | 2013-08-19 A | 2013-10-18 A | 20FS-10d | 100% |  |  |  |  |  |  |
| 52 | 10.2 | procurement |  | 4.5mo | 2013-10-21 A | 2014-02-27 A | 51 | 100% |  |  |  |  |  |  |
| 53 | 11 | **MQXFS Mirror structure** |  | 241d | 2013-08-12 A | 2014-07-22 A | 5, 6 | 100% |  |  | 986.4h | 986.4h | 135,435.89 | 135,435.89 |
| 54 | 11.1 | Conceptual design |  | 14w | 2013-08-12 A | 2013-11-15 A |  | 100% | start no earlier than 2013-08-12 | Engineer (Sr) - F [50%]; Scientist - F [12%] | 347.2h | 347.2h | 61,870.37 | 61,870.37 |
| 55 | 11.2 | FEM analysis |  | 33d | 2013-11-18 A | 2014-01-06 A | 54 | 100% |  | Engineer (Sr) - F [70%]; Scientist - F [10%] | 211.2h | 211.2h | 37,963.2 | 37,963.2 |
| 56 | 11.3 | preliminary design approved | milestone | 0d | 2014-01-10 A | 2014-01-10 A | 55 | 100% | start no earlier than 2014-01-10 |  |  |  |  |  |
| 57 | 11.4 | Drafting |  | 16d | 2014-01-10 A | 2014-02-03 A | 56 | 100% |  | Drafter - F | 128h | 128h | 8,079.36 | 8,079.36 |
| 58 | 11.5 | Final design approval | milestone | 0d | 2014-02-07 A | 2014-02-07 A | 57 | 100% | start no earlier than 2014-02-07 |  |  |  |  |  |
| 59 | 11.6 | Final drawings |  | 6d | 2014-02-07 A | 2014-02-14 A | 58 | 100% |  | Drafter - F [50%] | 24h | 24h | 1,514.88 | 1,514.88 |
| 60 | 11.7 | PO, quots, orders placed |  | 20d | 2014-02-17 A | 2014-03-14 A | 59 | 100% |  |  |  |  |  |  |
| 61 | 11.8 | Parts procurement |  | 14w | 2014-03-17 A | 2014-06-23 A | 60 | 100% |  | Technician - F [25%] | 140h | 140h | 10,844.4 | 10,844.4 |
| 62 | 11.9 | Inspection and QC |  | 4w | 2014-06-24 A | 2014-07-22 A | 61 | 100% |  | QC - F [75%]; Engineer (Sr) - F [10%] | 136h | 136h | 15,163.68 | 15,163.68 |
| 63 | 11.10 | Mirror Readiness Review | milestone | 0d | 2014-07-22 A | 2014-07-22 A | 62 | 100% | finish no earlier than 2014-07-20 |  |  |  |  |  |

| ID | WBS | Task | Type | Duration | Start | Finish | Predecessors | Complete | Remaining | Total slack | Free slack | Constraint |
| --- | --- | --- | --- | --- | --- | --- | --- | --- | --- | --- | --- | --- |
| 64 | 12 | **MQXFS Magnet structure (CERN)** |  | 312d | 2013-07-31 A | 2014-10-20 A | 5, 6 | 100% |  |  |  |  |
| 65 | 12.1 | Eng. design and drawings |  | 26w | 2013-07-31 A | 2014-02-03 A |  | 100% |  |  |  |  |
| 66 | 12.2 | Shell procurement |  | 26w | 2013-12-04 A | 2014-06-10 A | 65SS+18w | 100% |  |  |  |  |
| 67 | 12.3 | procurement and QC |  | 22w | 2014-02-04 A | 2014-07-09 A | 65 | 100% |  |  |  |  |
| 68 | 12.4 | Shipment to LBNL |  | 2w | 2014-08-25 A | 2014-09-08 A | 67 | 100% |  |  |  | start no earlier than 2014-08-24 |
| 69 | 12.5 | inspection & QC |  | 6w | 2014-09-09 A | 2014-10-20 A | 66, 68 | 100% |  |  |  |  |
| 70 | 13 | MQXFS structure inspected | milestone | 0d | 2014-10-20 A | 2014-10-20 A | 64 | 100% |  |  |  |  |
| 71 | 14 | **Dummy coils** |  | 125d | 2014-02-04 A | 2014-07-30 A |  | 100% |  |  |  |  |
| 72 | 14.1 | procure dummy coils |  | 5.5mo | 2014-02-04 A | 2014-07-09 A | 65 | 100% |  |  |  |  |
| 73 | 14.2 | instrumentation |  | 3w | 2014-07-10 A | 2014-07-30 A | 72 | 100% |  |  |  |  |
| 74 | 15 | **MQXFS Structure Assembly w dummy coils** |  | 123d | 2014-10-21 A | 2015-04-20 A | 70, 71 | 100% |  |  |  |  |
| 75 | 15.1 | structure instrumentation |  | 4w | 2014-10-21 A | 2014-11-17 A |  | 100% |  |  |  |  |
| 76 | 15.2 | pre-assembly |  | 4w | 2014-11-18 A | 2014-12-17 A | 64, 75 | 100% |  |  |  |  |
| 77 | 15.3 | assembly w dummy coils |  | 11w | 2015-01-12 A | 2015-03-30 A | 76 | 100% |  |  |  | start no earlier than 2015-01-11 |
| 78 | 15.4 | cold test |  | 3w | 2015-03-31 A | 2015-04-20 A | 77 | 100% |  |  |  |  |
| 79 | 16 | **Strand Procurement for QXF** |  | 1028d | 2013-03-25 A | 2017-04-14 |  | 38% | 641.4d | 80d |  |  |
| 80 | 16.1 | CDP Procurement 1, 180 kg |  | 262d | 2013-05-23 A | 2014-05-30 A |  | 100% |  |  |  | finish no earlier than 2014-05-30 |
| 81 | 16.2 | LARP Procurement 1, 275 kg |  | 288d | 2013-03-25 A | 2014-05-06 A |  | 100% |  |  |  | start no earlier than 2013-03-25 |
| 82 | 16.3 | CDP Procurement 2, 250 kg |  | 286d | 2014-04-10 A | 2015-05-29 A |  | 100% |  |  |  | finish no earlier than 2015-05-29 |
| 83 | 16.4 | LARP Procurement 2, 300 kg |  | 300d | 2014-11-14 | 2016-02-01 |  |  |  | 48d |  | start no earlier than 2014-11-14 |
| 84 | 16.5 | LARP Proc. shipment C |  | 404d | 2015-04-13 | 2016-11-15 |  |  |  | 45d | 0d | finish no earlier than 2016-11-15 |
| 85 | 16.6 | LARP Proc. Shipment D |  | 343d | 2015-10-05 | 2017-02-15 |  |  |  | 86d | 0d | finish no earlier than 2017-02-15 |
| 86 | 16.7 | CERN Procurement |  | 340d | 2015-12-09 | 2017-04-14 |  |  |  | 80d | 34d | finish no earlier than 2017-04-14 |
| 87 | 17 | **MQXFS Cabling & Insulation** |  | 274d | 2013-10-01 A | 2014-10-28 A |  | 100% |  |  |  |  |
| 88 | 17.1 | Cables for winding tests |  | 55d | 2013-10-01 A | 2013-12-16 A |  | 100% |  |  |  | start no earlier than 2013-10-01 |
| 89 | 17.2 | Cable for SQXF-PC L01 |  | 60d | 2013-10-21 A | 2014-01-15 A |  | 100% |  |  |  | finish no earlier than 2014-01-15 |
| 90 | 17.3 | Cable for SQXF-L02 |  | 65d | 2014-01-06 A | 2014-04-07 A |  | 100% |  |  |  | start no earlier than 2014-01-05 |
| 91 | 17.4 | Cable for SQXF-L03 |  | 60d | 2014-03-31 A | 2014-06-23 A |  | 100% |  |  |  | start no earlier than 2014-03-31 |
| 92 | 17.5 | Cable for Selva test |  | 40d | 2014-06-02 A | 2014-07-28 A |  | 100% |  |  |  | start no earlier than 2014-06-02 |
| 93 | 17.6 | Cable with 132/169 |  | 40d | 2014-07-01 A | 2014-08-26 A |  | 100% |  |  |  | start no earlier than 2014-07-01 |
| 94 | 17.7 | Cable for SQXF-L04, L05 |  | 40d | 2014-07-21 A | 2014-09-15 A |  | 100% |  |  |  | start no earlier than 2014-07-21 |
| 95 | 17.8 | Cable for SQXF- L06 -L08/Selva |  | 66d | 2014-07-28 A | 2014-10-28 A |  | 100% |  |  |  | start no earlier than 2014-07-27 |

| ID | WBS | Task | Type | Duration | Start | Finish | Predecessors | Complete | Remaining | Total slack | Free slack | Constraint | Resources | Work | Actual work | Cost | Actual cost |
| --- | --- | --- | --- | --- | --- | --- | --- | --- | --- | --- | --- | --- | --- | --- | --- | --- | --- |
| 96 | 18 | **MQXFS 2nd gen cables & ins** |  | 660d | 2015-03-23 A | 2017-10-30 |  | 51% | 324.59d | 157d |  |  |  |  |  |  |  |
| 97 | 18.1 | Cable for SQXF07 |  | 60d | 2015-03-23 A | 2015-06-15 A |  | 100% |  |  |  | start no earlier than 2015-03-22 |  |  |  |  |  |
| 98 | 18.2 | Cable for SQXF08 |  | 60d | 2015-06-08 A | 2015-08-31 A |  | 100% |  |  |  | start no earlier than 2015-06-07 |  |  |  |  |  |
| 99 | 18.3 | Cable for SQXF09 |  | 66d | 2015-07-13 A | 2015-10-13 A |  | 100% |  |  |  | start no earlier than 2015-07-12 |  |  |  |  |  |
| 100 | 18.4 | Cable for SQXF10 |  | 60d | 2016-05-30 | 2016-08-22 |  |  |  | 228d | 160d | start no earlier than 2016-05-29 |  |  |  |  |  |
| 101 | 18.5 | Cable for SQXF11 |  | 60d | 2016-07-18 | 2016-10-10 |  |  |  | 402d | 258d | start no earlier than 2016-07-17 |  |  |  |  |  |
| 102 | 18.6 | Cable for SQXF12 |  | 60d | 2017-08-07 | 2017-10-30 |  |  |  | 157d | 6d | start no earlier than 2017-08-06 |  |  |  |  |  |
| 103 | 19 | **MQXFA1 Magnet structure** |  | 620d | 2014-02-04 A | 2016-07-20 |  | 82% | 111.8d | 56d | 0d |  |  |  |  |  |  |
| 104 | 19.1 | Eng. Design |  | 72w | 2014-02-04 A | 2015-07-08 A | 65 | 100% |  |  |  |  |  |  |  |  |  |
| 105 | 19.2 | Structure design review | milestone | 0d | 2015-07-15 A | 2015-07-15 A | 104 | 100% |  |  |  | start no earlier than 2015-07-15 |  |  |  |  |  |
| 106 | 19.3 | drawings |  | 10.8w | 2015-07-15 A | 2015-09-29 A | 105 | 100% |  |  |  | finish no earlier than 2015-09-29 |  |  |  |  |  |
| 107 | 19.4 | structure procurement |  | 8.5mo | 2015-09-30 A | 2016-06-03 | 106 | 75% | 2.12mo | 10.75d | 0d | finish no earlier than 2016-06-03 |  |  |  |  |  |
| 108 | 19.5 | dummy coils procurement |  | 3mo | 2016-02-29 A | 2016-05-20 | 106 | 50% | 1.5mo | 19.75d | 9d | start no earlier than 2016-02-28 |  |  |  |  |  |
| 109 | 19.6 | Structure components at LBNL | milestone | 0d | 2016-06-03 | 2016-06-03 | 108, 107 |  |  | 10.75d | 0d |  |  |  |  |  |  |
| 110 | 19.7 | inspection & instrumentation |  | 14w | 2016-04-12 A | 2016-07-20 | 109FS-35d | 20% | 11.25w | 56d |  |  |  |  |  |  |  |
| 111 | 20 | **MQXFA assembly tooling** |  | 120d | 2016-02-01 A | 2016-07-19 |  | 35% | 77.5d | 87d | 31d |  |  |  |  |  |  |
| 112 | 20.1 | procurement |  | 17w | 2016-02-01 A | 2016-05-30 |  | 50% | 8.5w | 87d | 0d | start no earlier than 2016-02-01 |  |  |  |  |  |
| 113 | 20.2 | assembly |  | 7w | 2016-05-31 | 2016-07-19 | 112 |  |  | 87d |  |  |  |  |  |  |  |
| 114 | 21 | **MQXFA Structure Assembly w dummy coils** |  | 65d | 2016-07-21 | 2016-10-20 | 103 |  |  | 56d | 0d |  |  |  |  |  |  |
| 115 | 21.1 | yoke-shell sub-assembly |  | 6w | 2016-07-21 | 2016-08-31 |  |  |  | 56d | 0d |  |  |  |  |  |  |
| 116 | 21.2 | Mech model assembly |  | 5w | 2016-09-01 | 2016-10-06 | 115, 111 |  |  | 56d | 0d |  |  |  |  |  |  |
| 117 | 21.3 | Mech model complete | milestone | 0d | 2016-10-06 | 2016-10-06 | 116 |  |  | 56d | 0d |  |  |  |  |  |  |
| 118 | 21.4 | Mech model disassembly |  | 2w | 2016-10-07 | 2016-10-20 | 117 |  |  | 56d |  |  |  |  |  |  |  |
| 119 | 22 | **end optimization and practice** |  | 115d | 2013-09-16 A | 2014-02-27 A | 17 | 100% |  |  |  |  |  | 890.8h | 890.8h | 98,278.11 | 98,278.11 |
| 120 | 22.1 | Plastic Coil Parts by 3D printing at LBNL |  | 10d | 2013-09-16 A | 2013-09-27 A |  | 100% |  |  |  | start no earlier than 2013-09-16 |  |  |  |  |  |
| 121 | 22.2 | L1 practice wind with 30 m long cable at LBNL |  | 3d | 2013-10-09 A | 2013-10-11 A | 120 | 100% |  |  |  | start no earlier than 2013-10-09 |  |  |  |  |  |
| 122 | 22.3 | End Parts (epoxy) by CERN |  | 10d | 2013-10-21 A | 2013-11-01 A | 121FS+5d | 100% |  |  |  |  |  |  |  |  |  |
| 123 | 22.4 | decide parts for 1st PC | milestone | 0d | 2013-12-09 A | 2013-12-09 A | 122 | 100% |  |  |  | start no earlier than 2013-12-09 |  |  |  |  |  |
| 124 | 22.5 | End parts MLS by CERN |  | 20d | 2013-12-16 A | 2014-01-15 A | 121FS+5d, 123 | 100% |  |  |  | start no earlier than 2013-12-16 |  |  |  |  |  |
| 125 | 22.6 | 3D Prin SQXF Pole & Wedges by CERN |  | 10d | 2013-10-28 A | 2013-11-08 A | 121FS+10d | 100% |  |  |  |  |  |  |  |  |  |
| 126 | 22.7 | 1m coil practice W&C with BEND-ROXIE parts |  | 19d | 2013-12-18 A | 2014-01-16 A | 122, 11, 125, 88 | 100% |  |  |  | start no earlier than 2013-12-18 | QA - F [13%]; Engineer (Jr) - F [53%]; Technician - F [132%]; QC - F [200%] | 604.96h | 604.96h | 62,994.24 | 62,994.24 |
| 127 | 22.8 | Impregnation |  | 1d | 2014-01-17 A | 2014-01-17 A | 126 | 100% |  |  |  |  |  |  |  |  |  |
| 128 | 22.9 | Inspection |  | 3d | 2014-01-21 A | 2014-01-23 A | 127 | 100% |  |  |  |  | Engineer (Jr) - F; Technician - F [33%] | 31.92h | 31.92h | 4,595.32 | 4,595.32 |
| 129 | 22.10 | 3D Prin SQXF Pole & Wedges by CERN |  | 14d | 2014-01-13 A | 2014-01-31 A |  | 100% |  |  |  | start no earlier than 2014-01-13 |  |  |  |  |  |
| 130 | 22.11 | 1m coil practice W&C with ROXIE-BEND parts |  | 15d | 2014-02-03 A | 2014-02-21 A | 126, 129 | 100% |  |  |  |  | Engineer (Jr) - F [75%]; Technician - F; QA - F [10%] | 222h | 222h | 26,093.22 | 26,093.22 |
| 131 | 22.12 | Impregnation |  | 1d | 2014-02-24 A | 2014-02-24 A | 130 | 100% |  |  |  |  |  |  |  |  |  |
| 132 | 22.13 | Inspection |  | 3d | 2014-02-25 A | 2014-02-27 A | 131 | 100% |  |  |  |  | Engineer (Jr) - F; Technician - F [33%] | 31.92h | 31.92h | 4,595.32 | 4,595.32 |
| 133 | 22.14 | Comparison and Decision | milestone | 0d | 2014-02-27 A | 2014-02-27 A | 132 | 100% |  |  |  |  |  |  |  |  |  |

Notes:
- 122: 1 set BEND Parts and 1 set ROXIE Parts, plus some accodion parts for Practice Coil #1

| ID | WBS | Task | Type | Duration | Start | Finish | Predecessors | Complete | Remaining | Total slack | Free slack | Constraint |
| --- | --- | --- | --- | --- | --- | --- | --- | --- | --- | --- | --- | --- |
| 134 | 23 | **end parts 2nd iteration** |  | 75d | 2014-02-28 A | 2014-06-13 A | 133 | 100% |  |  |  |  |
| 135 | 23.1 | End parts 2nd Iteration Design |  | 15d | 2014-02-28 A | 2014-03-20 A |  | 100% |  |  |  |  |
| 136 | 23.2 | End Parts Procurement (MLS) at CERN |  | 20d | 2014-03-21 A | 2014-04-17 A | 135 | 100% |  |  |  |  |
| 137 | 23.3 | Coil #2 Plasma coating |  | 10d | 2014-04-18 A | 2014-05-01 A | 136 | 100% |  |  |  |  |
| 138 | 23.4 | End parts for Coil #3 procured | milestone | 0d | 2014-05-23 A | 2014-05-23 A |  | 100% |  |  |  | start no earlier than 2014-05-23 |
| 139 | 23.5 | Coil #3 parts coating |  | 15d | 2014-05-23 A | 2014-06-13 A | 138 | 100% |  |  |  |  |
| 140 | 24 | **MQXFA 1 Cabling and Insulation** |  | 433d | 2014-10-06 A | 2016-06-27 | 80, 81 | 84% | 70.36d | 627d |  |  |
| 141 | 24.1 | Cable for LQXF-PC01 |  | 80d | 2014-10-06 A | 2015-02-03 A |  | 100% |  |  |  | start no earlier than 2014-10-06 |
| 142 | 24.2 | Cable for LQXF-C02 |  | 80d | 2015-02-02 A | 2015-05-22 A |  | 100% |  |  |  | start no earlier than 2015-02-02 |
| 143 | 24.3 | Cable for LQXF-C03 |  | 80d | 2015-04-06 A | 2015-07-28 A |  | 100% |  |  |  | start no earlier than 2015-04-06 |
| 144 | 24.4 | Cable for LQXF-C04 |  | 80d | 2015-06-08 A | 2015-09-29 A |  | 100% |  |  |  | start no earlier than 2015-06-08 |
| 145 | 24.5 | Cable for LQXF-C05 |  | 80d | 2015-07-20 A | 2015-11-09 A | 82 | 100% |  |  |  | start no earlier than 2015-07-20 |
| 146 | 24.6 | Cable for LQXF-C06 |  | 80d | 2015-08-24 | 2015-12-16 |  |  |  | 759d | 174d | start no earlier than 2015-08-24 |
| 147 | 24.7 | Cable for QXFA-101 |  | 80d | 2016-03-07 A | 2016-06-27 |  | 86% | 11d | 4d |  | start no earlier than 2016-03-06 |
| 148 | 25 | **MQXFA 2 Cabling and Insulation** |  | 225d | 2016-04-08 | 2017-02-28 | 83 |  |  | 0d |  |  |
| 149 | 25.1 | Cable for QXFA102 |  | 80d | 2016-04-08 | 2016-08-01 |  |  |  | 0d |  | start no earlier than 2016-04-08 |
| 150 | 25.2 | Cable for QXFA103 |  | 80d | 2016-05-20 | 2016-09-13 |  |  |  | 100d | 18d | start no earlier than 2016-05-20 |
| 151 | 25.3 | Cable for QXFA104 |  | 40d | 2016-11-16 | 2017-01-17 | 84 |  |  | 45d | 0d | start no earlier than 2016-11-01 |
| 152 | 25.4 | Cable for QXFA105 |  | 70d | 2016-11-16 | 2017-02-28 | 84 |  |  | 45d | 0d | start no earlier than 2016-11-01 |
| 153 | 26 | **MQXFA PC coils Cabling and Insulation** |  | 317d | 2016-08-01 | 2017-10-30 |  |  |  | 22d |  |  |
| 154 | 26.1 | Cable for QXFA200 or S/LQXF PC coil @BNL |  | 80d | 2016-08-01 | 2016-11-21 |  |  |  | 189d |  | start no earlier than 2016-07-31 |
| 155 | 26.2 | Cable for QXFA201 |  | 80d | 2017-07-10 | 2017-10-30 | 86 |  |  | 22d |  | start no earlier than 2017-07-09 |
| 156 | 27 | **MQXFA3 Cabling and Insulation** |  | 292d | 2017-02-16 | 2018-04-12 |  |  |  | 0d |  |  |
| 157 | 27.1 | Cable for QXFA106 |  | 80d | 2017-02-16 | 2017-06-08 | 85 |  |  | 86d | 0d | start no earlier than 2017-01-20 |
| 158 | 27.2 | Cable for QXFA107 |  | 80d | 2017-03-17 | 2017-07-10 | 85 |  |  | 95d | 9d | start no earlier than 2017-03-17 |
| 159 | 27.3 | Cable for QXFA202 |  | 80d | 2017-12-18 | 2018-04-12 | 86 |  |  | 0d |  | start no earlier than 2017-12-18 |
| 160 | 27.4 | Cable for QXFA108 |  | 80d | 2017-06-05 | 2017-09-26 | 86 |  |  | 88d | 0d | start no earlier than 2017-06-04 |
| 161 | 27.5 | Cable for QXFA109 |  | 80d | 2017-08-14 | 2017-12-06 | 86 |  |  | 87d | 0d | start no earlier than 2017-08-13 |
| 162 | 28 | Start Practice Coils - RM | milestone | 0d | 2014-03-05 A | 2014-03-05 A | 23, 38, 89, 124, 130 | 100% |  |  |  | start no earlier than 2014-03-05 |

Notes:
- 136: 8 sets from coil 1 through 8

| ID | WBS | Task | Type | Duration | Start | Finish | Predecessors | Complete | Constraint | Resources | Work | Actual work | Cost | Actual cost |
| --- | --- | --- | --- | --- | --- | --- | --- | --- | --- | --- | --- | --- | --- | --- |
| 163 | 29 | **Practice Coil QXFS#1** |  | 143d | 2014-03-05 A | 2014-09-24 A | 162 | 100% |  |  | 1857.84h | 1857.84h | 186,187.49 | 186,187.49 |
| 164 | 29.1 | Coil Wind / Cure |  | 30d | 2014-03-05 A | 2014-04-15 A | 162 | 100% |  | Technician - F [200%]; Engineer (Jr) - F [67%]; QA - F [50%]; QC - F [110%] | 894h | 894h | 87,752.58 | 87,752.58 |
| 165 | 29.2 | Coil shipment |  | 20d | 2014-04-16 A | 2014-05-13 A | 164 | 100% |  |  |  |  |  |  |
| 166 | 29.3 | Coil React |  | 33d | 2014-05-14 A | 2014-06-30 A | 48FS-30d, 165 | 100% |  | Engineer (Sr) - F [26%]; QA - F [10%]; Technician - F [105%] | 372.24h | 372.24h | 38,109.66 | 38,109.67 |
| 167 | 29.4 | Coil Impreg |  | 45d | 2014-07-01 A | 2014-09-03 A | 166, 34 | 100% |  | Engineer (Sr) - F [26%]; QA - F [10%]; Technician - F [105%] | 507.6h | 507.6h | 51,967.73 | 51,967.73 |
| 168 | 29.5 | Coil QA & inspection |  | 15d | 2014-09-04 A | 2014-09-24 A | 167 | 100% |  | Engineer (Sr) - F [10%]; QC - F [20%]; Technician - F [40%] | 84h | 84h | 8,357.52 | 8,357.52 |
| 169 | 30 | QXF Coil Workshop, CM22 | milestone | 0d | 2014-05-09 A | 2014-05-09 A |  | 100% | start no earlier than 2014-05-09 |  |  |  |  |  |
| 170 | 31 | Start Practice Coils #2 - RM | milestone | 0d | 2014-05-16 A | 2014-05-16 A | 21, 169FS+6d, 90, 137 | 100% |  |  |  |  |  |  |
| 171 | 32 | **Coil QXFS#2 (for mirror test)** |  | 121d | 2014-05-19 A | 2014-11-06 A | 170 | 100% |  |  | 1269.04h | 1269.04h | 129,600.43 | 129,600.43 |
| 172 | 32.1 | Coil Wind / Cure |  | 25d | 2014-05-19 A | 2014-06-23 A |  | 100% |  | Technician - F [200%]; Engineer (Jr) - F [67%]; QA - F [17%]; QC - F [7%] | 582h | 582h | 59,931.56 | 59,931.56 |
| 173 | 32.2 | Coil React |  | 23d | 2014-07-03 A | 2014-09-04 A | 172 | 100% | start no earlier than 2014-07-03 | Engineer (Sr) - F [26%]; QA - F [5%]; Technician - F [105%] | 250.24h | 250.24h | 25,130.59 | 25,130.59 |
| 174 | 32.3 | Coil Impreg |  | 35d | 2014-09-05 A | 2014-10-23 A | 173 | 100% |  | Engineer (Sr) - F [26%]; QA - F [5%]; Technician - F [105%] | 380.8h | 380.8h | 38,799.45 | 38,799.45 |
| 175 | 32.4 | Coil instrumentation (FNAL) |  | 10d | 2014-10-24 A | 2014-11-06 A | 174 | 100% |  | Engineer (Sr) - F [10%]; QC - F [20%]; Technician - F [40%] | 56h | 56h | 5,738.83 | 5,738.83 |
| 176 | 33 | Mirror assembly Readyness Rev | milestone | 0d | 2014-11-06 A | 2014-11-06 A | 171, 53 | 100% |  |  |  |  |  |  |
| 177 | 34 | **MQXFS mirror assembly** |  | 81d | 2014-11-07 A | 2015-03-10 A | 176 | 100% |  |  | 1482h | 1482h | 148,772.75 | 148,772.75 |
| 178 | 34.1 | Assembly |  | 6w | 2014-11-07 A | 2014-12-22 A |  | 100% |  | Engineer (Sr) - F [33%]; Technician - F [200%] | 559.2h | 559.2h | 53,190.37 | 53,190.37 |
| 179 | 34.2 | In the press |  | 5w | 2015-01-05 A | 2015-02-10 A | 178 | 100% | start no earlier than 2015-01-05 | Engineer (Sr) - F [75%]; Technician - F [200%] | 550h | 550h | 60,122.13 | 60,122.13 |
| 180 | 34.3 | Final prep |  | 4w | 2015-02-11 A | 2015-03-10 A | 179 | 100% |  | Engineer (Sr) - F [33%]; Technician - F [200%] | 372.8h | 372.8h | 35,460.25 | 35,460.25 |
| 181 | 35 | New Top Head commissioned | milestone | 0d | 2015-04-10 A | 2015-04-10 A |  | 100% | start no earlier than 2015-04-10 |  |  |  |  |  |
| 182 | 36 | Test preparation |  | 12d | 2015-04-10 A | 2015-04-27 A | 181 | 100% |  |  |  |  |  |  |
| 183 | 37 | Mirror test |  | 5w | 2015-04-28 A | 2015-06-02 A | 177, 182 | 100% |  |  |  |  |  |  |
| 184 | 38 | MQXFS_Mirror Test Analysis |  | 4w | 2015-06-03 A | 2015-06-30 A | 183 | 100% |  |  |  |  |  |  |
| 185 | 39 | Mirror disassembly |  | 3w | 2015-07-06 A | 2015-07-31 A | 184 | 100% | start no earlier than 2015-07-06 |  |  |  |  |  |
| 186 | 40 | Assembly tests for MQXFP mirror |  | 2w | 2015-08-03 A | 2015-08-14 A | 185 | 100% |  |  |  |  |  |  |

| ID | WBS | Task | Type | Duration | Start | Finish | Predecessors | Complete | Remaining | Total slack | Free slack | Constraint | Resources | Work | Actual work | Cost | Actual cost |
| --- | --- | --- | --- | --- | --- | --- | --- | --- | --- | --- | --- | --- | --- | --- | --- | --- | --- |
| 187 | 41 | **MQXFS_2nd_mirror** |  | 110d | 2015-08-17 | 2016-01-27 | 186 |  |  | 844d |  |  |  |  |  |  |  |
| 188 | 41.1 | **SQXFM2 mirror asmbly, test pre** |  | 65d | 2015-08-17 | 2015-11-16 |  |  |  | 844d |  |  |  |  |  |  |  |
| 189 | 41.1.1 | Assembly |  | 6w | 2015-08-17 | 2015-09-28 |  |  |  | 844d | 0d |  |  |  |  |  |  |
| 190 | 41.1.2 | In the press |  | 4w | 2015-09-29 | 2015-10-26 | 189 |  |  | 844d | 0d |  |  |  |  |  |  |
| 191 | 41.1.3 | Final prep |  | 3w | 2015-10-27 | 2015-11-16 | 190 |  |  | 844d | 0d |  |  |  |  |  |  |
| 192 | 41.2 | Mirror test |  | 5w | 2015-11-17 | 2015-12-23 | 191 |  |  | 844d | 0d |  |  |  |  |  |  |
| 193 | 41.3 | SQXFM2 Test Analysis |  | 4w | 2015-12-28 | 2016-01-27 | 192 |  |  | 844d |  |  |  |  |  |  |  |
| 194 | 41.4 | Mirror disassembly |  | 3w | 2015-12-28 | 2016-01-20 | 192 |  |  | 849d |  |  |  |  |  |  |  |
| 195 | 42 | **HQ feedback** |  | 62d | 2014-02-03 A | 2014-04-29 A |  | 100% |  |  |  |  |  |  |  |  |  |
| 196 | 42.1 | HQ02b shipment to CERN |  | 10d | 2014-02-03 A | 2014-02-14 A |  | 100% |  |  |  | start no earlier than 2014-02-03 |  |  |  |  |  |
| 197 | 42.2 | HQ02b Test at CERN |  | 30d | 2014-02-17 A | 2014-03-28 A | 196 | 100% |  |  |  |  |  |  |  |  |  |
| 198 | 42.3 | HQ02b test analysis |  | 10d | 2014-03-31 A | 2014-04-11 A | 197 | 100% |  |  |  |  |  |  |  |  |  |
| 199 | 42.4 | feedback to QXF coils |  | 12d | 2014-04-14 A | 2014-04-29 A | 198 | 100% |  |  |  |  |  |  |  |  |  |
| 200 | 43 | QXF QP workshop | milestone | 0d | 2014-04-29 A | 2014-04-29 A | 195 | 100% |  |  |  |  |  |  |  |  |  |
| 201 | 44 | **Coil QXFS#3** |  | 159d | 2014-07-14 A | 2015-03-03 A | 91, 195, 200 | 100% |  |  |  |  |  | 1378.96h | 1378.96h | 169,707.01 | 169,707.01 |
| 202 | 44.1 | Coil Wind / Cure |  | 15d | 2014-07-14 A | 2014-08-01 A | 172, 138 | 100% |  |  |  | start no earlier than 2014-07-14 | Technician - F [200%]; Engineer (Jr) - F [67%]; QA - F [17%]; QC - F [57%] | 409.2h | 409.2h | 42,080.14 | 42,080.14 |
| 203 | 44.2 | Coil shipment |  | 12d | 2014-08-04 A | 2014-08-19 A | 202 | 100% |  |  |  |  | Engineer (Jr) - F [2%]; Technician - F [16%] | 17.28h | 17.28h | 1,508.33 | 1,508.33 |
| 204 | 44.3 | Coil React |  | 23d | 2014-08-20 A | 2014-09-22 A | 203 | 100% |  |  |  |  | Engineer (Sr) - B [25%]; Technician - B [65%]; Technician Supervisor - B [10%] | 184h | 184h | 23,890.38 | 23,890.38 |
| 205 | 44.4 | Coil Impreg |  | 35d | 2014-10-20 A | 2014-12-09 A | 204, 35 | 100% |  |  |  | start no earlier than 2014-10-19 | Engineer (Sr) - B [50%]; Technician - B [186%]; Technician Supervisor - B [10%] | 688.8h | 688.8h | 89,491.5 | 89,491.5 |
| 206 | 44.5 | Coil QA & shipment |  | 12d | 2015-02-02 A | 2015-02-17 A | 205 | 100% |  |  |  | start no earlier than 2015-02-01 | Engineer (Sr) - B [66%]; Technician Supervisor - B [17%] | 79.68h | 79.68h | 12,736.66 | 12,736.66 |
| 207 | 44.6 | Coil instrumentation |  | 10d | 2015-02-18 A | 2015-03-03 A | 206 | 100% |  |  |  |  |  |  |  |  |  |
| 208 | 45 | end spacer adjustments & fabr. |  | 13w | 2014-08-04 A | 2014-11-03 A | 166 | 100% |  |  |  | start no earlier than 2014-08-03 |  |  |  |  |  |
| 209 | 46 | **Coil QXFS#4 (asym test)** |  | 167d | 2014-11-04 A | 2015-07-07 | 94, 208 | 53% | 79.11d | 982d |  |  |  | 426.48h | 426.48h | 44,896.12 | 44,896.12 |
| 210 | 46.1 | Coil Wind / Cure |  | 15d | 2014-11-04 A | 2014-12-12 A | 202 | 100% |  |  |  |  | Technician - F [200%]; Engineer (Jr) - F [67%]; QA - F [17%]; QC - F [57%] | 409.2h | 409.2h | 43,342.54 | 43,342.54 |
| 211 | 46.2 | Coil shipment |  | 12d | 2015-01-06 A | 2015-01-23 A | 210 | 100% |  |  |  | start no earlier than 2015-01-06 | Engineer (Jr) - F [2%]; Technician - F [16%] | 17.28h | 17.28h | 1,553.58 | 1,553.58 |
| 212 | 46.3 | Coil React |  | 23d | 2015-03-02 A | 2015-04-01 A | 211 | 100% |  |  |  | start no earlier than 2015-03-01 |  |  |  |  |  |
| 213 | 46.4 | Coil Impreg |  | 35d | 2015-05-04 | 2015-06-22 | 212 |  |  | 982d | 0d | start no earlier than 2015-05-03 |  |  |  |  |  |
| 214 | 46.5 | Coil instrumentation |  | 10d | 2015-06-23 | 2015-07-07 | 207, 213 |  |  | 982d |  |  |  |  |  |  |  |

| ID | WBS | Task | Type | Duration | Start | Finish | Predecessors | Complete | Constraint |
| --- | --- | --- | --- | --- | --- | --- | --- | --- | --- |
| 215 | 47 | **Coil QXFS#5 - R&I BNL** |  | 113d | 2014-12-15 A | 2015-05-28 A | 94 | 100% |  |
| 216 | 47.1 | Coil Wind / Cure |  | 21d | 2014-12-15 A | 2015-01-16 A | 210 | 100% |  |
| 217 | 47.2 | Coil shipment |  | 12d | 2015-01-20 A | 2015-02-04 A | 216 | 100% |  |
| 218 | 47.3 | Coil React |  | 23d | 2015-02-05 A | 2015-03-09 A | 173FS+20d, 217 | 100% |  |
| 219 | 47.4 | Coil Impreg |  | 35d | 2015-03-10 A | 2015-04-27 A | 218 | 100% |  |
| 220 | 47.5 | Coil shipment |  | 12d | 2015-04-28 A | 2015-05-13 A | 219 | 100% |  |
| 221 | 47.6 | Coil instrumentation |  | 10d | 2015-05-14 A | 2015-05-28 A | 220 | 100% |  |
| 222 | 48 | **Coil QXFS#6 - R&I FNAL** |  | 135d | 2015-02-10 A | 2015-08-19 A | 95 | 100% |  |
| 223 | 48.1 | Insulated cable delivered | milestone | 0d | 2015-02-10 A | 2015-02-10 A |  | 100% | start no earlier than 2015-02-10 |
| 224 | 48.2 | Coil Wind / Cure |  | 15d | 2015-02-10 A | 2015-03-02 A | 216, 223 | 100% |  |
| 225 | 48.3 | Coil React |  | 23d | 2015-03-16 A | 2015-04-15 A | 204FS+20d, 224 | 100% | start no earlier than 2015-03-15 |
| 226 | 48.4 | Coil Impreg |  | 43d | 2015-05-27 A | 2015-07-27 A | 225 | 100% | start no earlier than 2015-05-27 |
| 227 | 48.5 | Electrical QA and CMM |  | 5d | 2015-07-28 A | 2015-08-03 A | 226 | 100% |  |
| 228 | 48.6 | Coil shipment |  | 12d | 2015-08-04 A | 2015-08-19 A | 227 | 100% |  |
| 229 | 49 | **Coil 103 (CERN)** |  | 15d | 2015-03-27 A | 2015-04-16 A |  | 100% |  |
| 230 | 49.1 | Coil completed | milestone | 0d | 2015-03-27 A | 2015-03-27 A |  | 100% | start no earlier than 2015-03-27 |
| 231 | 49.2 | Shipment and custom |  | 15d | 2015-03-27 A | 2015-04-16 A | 230 | 100% |  |
| 232 | 50 | **Coil 104 (CERN)** |  | 17d | 2015-05-11 A | 2015-06-03 A |  | 100% |  |
| 233 | 50.1 | Coil completed | milestone | 0d | 2015-05-11 A | 2015-05-11 A |  | 100% | start no earlier than 2015-05-11 |
| 234 | 50.2 | Shipment and custom |  | 17d | 2015-05-11 A | 2015-06-03 A | 233 | 100% |  |
| 235 | 51 | MQXFS1 Assembly Read. Rev - RM | milestone | 0d | 2015-06-03 A | 2015-06-03 A | 201, 215, 5, 229, 232, 74 | 100% |  |
| 236 | 52 | **MQXFS1_AssemblyTest @ LARP** |  | 119d | 2015-06-04 A | 2015-11-19 A | 235 | 100% |  |
| 237 | 52.1 | Coils CMM, QA and connectors |  | 5d | 2015-06-04 A | 2015-06-10 A |  | 100% |  |
| 238 | 52.2 | Assembly & loading |  | 11w | 2015-06-11 A | 2015-09-02 A | 237 | 100% |  |
| 239 | 52.3 | Splice box |  | 2w | 2015-09-03 A | 2015-09-17 A | 238 | 100% |  |
| 240 | 52.4 | QA & shipment prep |  | 3w | 2015-09-18 A | 2015-10-08 A | 239 | 100% |  |
| 241 | 52.5 | shipment |  | 2w | 2015-10-09 A | 2015-10-22 A | 240 | 100% |  |
| 242 | 52.6 | Test prep |  | 4w | 2015-10-23 A | 2015-11-19 A | 241 | 100% |  |
| 243 | 53 | Test start |  | 5d | 2015-11-20 A | 2015-11-30 A | 236 | 100% |  |
| 244 | 54 | Repair |  | 3w | 2015-12-01 A | 2015-12-21 A | 243 | 100% |  |
| 245 | 55 | Cryoplant maintenance |  | 6w | 2015-12-22 A | 2016-02-08 A | 244 | 100% |  |

| ID | WBS | Task | Type | Duration | Start | Finish | Predecessors | Complete | Remaining | Total slack | Free slack |
| --- | --- | --- | --- | --- | --- | --- | --- | --- | --- | --- | --- |
| 246 | 56 | **MQXFS1 Test after repair** |  | 59d | 2016-02-09 A | 2016-04-29 A | 245 | 100% |  |  |  |
| 247 | 56.1 | Test preparation |  | 10d | 2016-02-09 A | 2016-02-22 A |  | 100% |  |  |  |
| 248 | 56.2 | Test |  | 44d | 2016-02-23 A | 2016-04-22 A | 247 | 100% |  |  |  |
| 249 | 56.3 | Warm-up |  | 5d | 2016-04-25 A | 2016-04-29 A | 248 | 100% |  |  |  |
| 250 | 57 | MQXFS Test analysis |  | 6w | 2016-04-25 A | 2016-06-06 | 248 | 25% | 4.5w | 152d | 0d |
| 251 | 58 | MQXFS Test Review | milestone | 0d | 2016-06-06 | 2016-06-06 | 250 |  |  | 152d | 96d |
| 252 | 59 | **MQXFS1b** |  | 48d | 2016-04-29 | 2016-07-08 | 222, 246 |  |  | 129d | 0d |
| 253 | 59.1 | Shipment to LBNL |  | 10d | 2016-05-02 | 2016-05-13 |  |  |  | 129d | 0d |
| 254 | 59.2 | MQXFS01b Readiness Review | milestone | 0d | 2016-04-29 | 2016-04-29 |  |  |  | 139d | 10d |
| 255 | 59.3 | Preload incr. & strain gauge repair |  | 20d | 2016-05-16 | 2016-06-13 | 254, 253 |  |  | 129d | 0d |
| 256 | 59.4 | shipment preparation |  | 5d | 2016-06-14 | 2016-06-20 | 255 |  |  | 129d | 0d |
| 257 | 59.5 | shipment |  | 5d | 2016-06-21 | 2016-06-27 | 256 |  |  | 129d | 0d |
| 258 | 59.6 | Test prep |  | 8d | 2016-06-28 | 2016-07-08 | 257 |  |  | 129d |  |
| 259 | 60 | CLIQ into VMTF integr & commis |  | 10d | 2016-07-11 | 2016-07-22 | 252 |  |  | 129d | 0d |
| 260 | 61 | Test |  | 30d | 2016-07-25 | 2016-09-02 | 259 |  |  | 129d | 0d |
| 261 | 62 | Test analysis |  | 6w | 2016-09-06 | 2016-10-17 | 260 |  |  | 659d | 0d |
| 262 | 63 | Review | milestone | 0d | 2016-10-17 | 2016-10-17 | 261 |  |  | 659d |  |
| 263 | 64 | **MQXFS1c w SS skin** |  | 35d | 2016-09-06 | 2016-10-24 | 260 |  |  | 129d | 0d |
| 264 | 64.1 | setup |  | 10d | 2016-09-06 | 2016-09-19 |  |  |  | 129d | 0d |
| 265 | 64.2 | alignment tests |  | 10d | 2016-09-20 | 2016-10-03 | 264 |  |  | 129d | 0d |
| 266 | 64.3 | SS skin welding |  | 10d | 2016-10-04 | 2016-10-17 | 265 |  |  | 129d | 0d |
| 267 | 64.4 | test prep |  | 5d | 2016-10-18 | 2016-10-24 | 266 |  |  | 129d |  |
| 268 | 65 | Test |  | 5w | 2016-10-25 | 2016-11-30 | 263 |  |  | 129d | 0d |
| 269 | 66 | Test analysis |  | 6w | 2016-12-01 | 2017-01-13 | 268 |  |  | 599d | 0d |
| 270 | 67 | Review | milestone | 0d | 2017-01-13 | 2017-01-13 | 269 |  |  | 599d |  |

| ID | WBS | Task | Type | Duration | Start | Finish | Predecessors | Complete | Remaining | Total slack | Free slack | Constraint |
| --- | --- | --- | --- | --- | --- | --- | --- | --- | --- | --- | --- | --- |
| 271 | 68 | **LARP coils to CERN for MQXFS2** |  | 192d | 2015-08-17 A | 2016-05-20 |  | 78% | 42.35d | 762d |  |  |
| 272 | 68.1 | Coil QXFS#6 CMM & instrumentation |  | 13d | 2015-08-31 A | 2015-09-17 A | 228 | 100% |  |  |  | start no earlier than 2015-08-30 |
| 273 | 68.2 | Coil #6 shipment to CERN |  | 3w | 2016-04-11 A | 2016-04-29 A |  | 100% |  |  |  | start no earlier than 2016-04-11 |
| 274 | 68.3 | Coil QXFS#2 shipment to LBNL |  | 12d | 2015-08-17 A | 2015-09-01 A | 186 | 100% |  |  |  |  |
| 275 | 68.4 | Coil QXFS#2 CMM & instrumentation |  | 13d | 2016-01-11 A | 2016-01-28 A | 272, 274 | 100% |  |  |  | start no earlier than 2016-01-10 |
| 276 | 68.5 | Coil #2 shipment to CERN |  | 3w | 2016-05-02 | 2016-05-20 | 275 |  |  | 762d |  | start no earlier than 2016-05-01 |
| 277 | 69 | MQXFS2 Readiness Review | milestone | 0d | 2016-04-25 | 2016-04-25 |  |  |  | 148d | 5d | start no earlier than 2016-04-25 |
| 278 | 70 | **MQXFS2 assembly @ CERN** |  | 62d | 2016-05-02 | 2016-07-28 | 277, 273 |  |  | 143d | 0d |  |
| 279 | 70.1 | Assembly & loading |  | 40d | 2016-05-02 | 2016-06-27 |  |  |  | 143d | 0d |  |
| 280 | 70.2 | pizza box & QA |  | 5d | 2016-06-28 | 2016-07-05 | 279 |  |  | 143d | 0d |  |
| 281 | 70.3 | delivery to test facility |  | 7d | 2016-07-06 | 2016-07-14 | 280 |  |  | 143d | 0d |  |
| 282 | 70.4 | Test prep |  | 10d | 2016-07-15 | 2016-07-28 | 281 |  |  | 143d |  |  |
| 283 | 71 | Test |  | 45d | 2016-07-29 | 2016-09-30 | 278 |  |  | 143d | 0d |  |
| 284 | 72 | Review | milestone | 0d | 2016-09-30 | 2016-09-30 | 283 |  |  | 670d |  |  |
| 285 | 73 | Decision: new cable & expansion | milestone | 0d | 2015-02-27 A | 2015-02-27 A |  | 100% |  |  |  | start no earlier than 2015-02-27 |
| 286 | 74 | Develop 2nd gen x-section |  | 4w | 2015-02-27 A | 2015-03-26 A | 285 | 100% |  |  |  |  |
| 287 | 75 | Decision: 2nd gen x-section | milestone | 0d | 2015-03-26 A | 2015-03-26 A | 286 | 100% |  |  |  | start no earlier than 2015-03-02 |
| 288 | 76 | **Design & Fabrication new parts** |  | 190d | 2015-03-27 A | 2015-12-28 A | 287 | 100% |  |  |  |  |
| 289 | 76.1 | wedges by machining |  | 21w | 2015-07-06 A | 2015-12-02 A |  | 100% |  |  |  | start no earlier than 2015-07-05 |
| 290 | 76.2 | wedges by extrusion |  | 38w | 2015-03-27 A | 2015-12-28 A |  | 100% |  |  |  | finish no earlier than 2015-08-21 |
| 291 | 76.3 | Pole parts |  | 24w | 2015-03-27 A | 2015-09-15 A |  | 100% |  |  |  |  |
| 292 | 76.4 | End parts |  | 28w | 2015-03-27 A | 2015-10-13 A |  | 100% |  |  |  |  |
| 293 | 76.5 | End parts coating |  | 4w | 2015-10-14 A | 2015-11-10 A | 292 | 100% |  |  |  |  |
| 294 | 77 | **Coil QXFS#7 (1st 2nd gen)** |  | 136d | 2015-12-03 A | 2016-06-17 | 183, 97, 291, 289, 293 | 91% | 12.59d | 161d | 11d |  |
| 295 | 77.1 | Coil Wind / Cure |  | 15d | 2015-12-03 A | 2015-12-23 A | 224 | 100% |  |  |  |  |
| 296 | 77.2 | Coil React |  | 23d | 2015-12-28 A | 2016-02-01 A | 218FS+20d, 295 | 100% |  |  |  |  |
| 297 | 77.3 | Coil Impreg |  | 35d | 2016-02-02 A | 2016-03-28 A | 296 | 100% |  |  |  |  |
| 298 | 77.4 | Coil shipment to CERN |  | 25d | 2016-03-29 A | 2016-06-03 A | 297 | 100% |  |  |  |  |
| 299 | 77.5 | Coil instrumentation |  | 10d | 2016-06-06 | 2016-06-17 | 298 |  |  | 161d |  | start no earlier than 2016-05-01 |

| ID | WBS | Task | Type | Duration | Start | Finish | Predecessors | Complete | Remaining | Total slack | Free slack | Constraint |
| --- | --- | --- | --- | --- | --- | --- | --- | --- | --- | --- | --- | --- |
| 300 | 78 | **Coil QXFS#8** |  | 194d | 2016-03-21 A | 2016-12-22 | 98, 288 | 37% | 121.48d | 613d |  |  |
| 301 | 78.1 | End parts ready | milestone | 0d | 2016-03-21 A | 2016-03-21 A |  | 100% |  |  |  | start no earlier than 2016-03-21 |
| 302 | 78.2 | Coil Wind / Cure |  | 15d | 2016-03-21 A | 2016-05-02 A | 295, 301 | 100% |  |  |  |  |
| 303 | 78.3 | Coil shipment |  | 12d | 2016-05-03 A | 2016-05-18 A | 302 | 100% |  |  |  |  |
| 304 | 78.4 | Coil React |  | 23d | 2016-06-01 A | 2016-07-04 | 303, 440FS-5d | 57% | 10d | 448d | 0d | start no earlier than 2016-06-01 |
| 305 | 78.5 | Coil Impreg |  | 35d | 2016-10-03 | 2016-11-18 | 304 |  |  | 613d | 0d | start no earlier than 2016-10-03 |
| 306 | 78.6 | Coil shipment |  | 12d | 2016-11-21 | 2016-12-08 | 305 |  |  | 613d | 0d |  |
| 307 | 78.7 | Coil instrumentation |  | 10d | 2016-12-09 | 2016-12-22 | 306 |  |  | 613d |  |  |
| 308 | 79 | BNL oven extension |  | 60d | 2016-07-05 | 2016-09-27 | 304 |  |  | 448d | 304d | start no earlier than 2016-07-05 |
| 309 | 80 | **Coil QXFS#9** |  | 107d | 2016-12-07 | 2017-05-09 | 342, 99FS+10d |  |  | 143d | 108d |  |
| 310 | 80.1 | Coil Wind / Cure |  | 15d | 2016-12-07 | 2016-12-28 | 510 |  |  | 143d | 0d | start no earlier than 2016-11-14 |
| 311 | 80.2 | Coil shipment |  | 12d | 2016-12-29 | 2017-01-17 | 310 |  |  | 143d | 0d |  |
| 312 | 80.3 | Coil React |  | 23d | 2017-01-18 | 2017-02-17 | 311, 506 |  |  | 143d | 0d |  |
| 313 | 80.4 | Coil Impreg |  | 35d | 2017-02-20 | 2017-04-07 | 312 |  |  | 143d | 0d |  |
| 314 | 80.5 | Coil shipment |  | 12d | 2017-04-10 | 2017-04-25 | 313 |  |  | 143d | 0d |  |
| 315 | 80.6 | Coil instrumentation |  | 10d | 2017-04-26 | 2017-05-09 | 314 |  |  | 143d | 98d |  |
| 316 | 81 | **Coil QXFS#10** |  | 118d | 2017-04-26 | 2017-10-11 | 100FS+10d |  |  | 45d | 0d |  |
| 317 | 81.1 | Coil Wind / Cure |  | 15d | 2017-04-26 | 2017-05-16 | 310, 523 |  |  | 68d | 23d | start no earlier than 2016-10-03 |
| 318 | 81.2 | Coil React |  | 23d | 2017-06-20 | 2017-07-21 | 317, 525FS-20d |  |  | 45d | 0d | start no earlier than 2015-10-01 |
| 319 | 81.3 | Coil Impreg |  | 35d | 2017-07-24 | 2017-09-11 | 318 |  |  | 45d | 0d |  |
| 320 | 81.4 | Coil shipment |  | 12d | 2017-09-12 | 2017-09-27 | 319 |  |  | 45d | 0d |  |
| 321 | 81.5 | Coil instrumentation |  | 10d | 2017-09-28 | 2017-10-11 | 315, 320 |  |  | 45d |  |  |
| 322 | 82 | **Coil QXFS#11 (spare or FQ adj.)** |  | 107d | 2017-11-01 | 2018-04-06 | 469, 101FS+10d |  |  | 144d | 10d |  |
| 323 | 82.1 | Coil Wind / Cure |  | 15d | 2017-11-01 | 2017-11-21 | 317 |  |  | 144d | 0d | start no earlier than 2016-10-03 |
| 324 | 82.2 | Coil shipment |  | 12d | 2017-11-22 | 2017-12-11 | 323 |  |  | 144d | 0d |  |
| 325 | 82.3 | Coil React |  | 23d | 2017-12-12 | 2018-01-17 | 324, 308 |  |  | 144d | 0d |  |
| 326 | 82.4 | Coil Impreg |  | 35d | 2018-01-18 | 2018-03-07 | 325 |  |  | 144d | 0d |  |
| 327 | 82.5 | Coil shipment |  | 12d | 2018-03-08 | 2018-03-23 | 326 |  |  | 144d | 0d |  |
| 328 | 82.6 | Coil instrumentation |  | 10d | 2018-03-26 | 2018-04-06 | 327, 321 |  |  | 144d | 0d |  |

| ID | WBS | Task | Type | Duration | Start | Finish | Predecessors | Complete | Remaining | Total slack | Free slack | Constraint |
| --- | --- | --- | --- | --- | --- | --- | --- | --- | --- | --- | --- | --- |
| 329 | 83 | **Coil QXFS#12 (FQ adjustment)** |  | 102d | 2017-11-22 | 2018-04-20 | 469, 102FS+10d |  |  | 144d | 0d |  |
| 330 | 83.1 | Coil Wind / Cure |  | 15d | 2017-11-22 | 2017-12-14 | 323 |  |  | 151d | 0d | start no earlier than 2017-10-02 |
| 331 | 83.2 | Coil React |  | 23d | 2017-12-15 | 2018-01-22 | 330, 319 |  |  | 151d | 0d |  |
| 332 | 83.3 | Coil Impreg |  | 35d | 2018-01-23 | 2018-03-12 | 331 |  |  | 151d | 0d |  |
| 333 | 83.4 | Coil shipment |  | 12d | 2018-03-13 | 2018-03-28 | 332 |  |  | 151d | 7d |  |
| 334 | 83.5 | Coil instrumentation |  | 10d | 2018-04-09 | 2018-04-20 | 333, 328 |  |  | 144d |  |  |
| 335 | 84 | CERN coil 105 completed | milestone | 0d | 2016-02-11 | 2016-02-11 |  |  |  | 252d | 102d | start no earlier than 2016-02-11 |
| 336 | 85 | CERN coil 106 completed | milestone | 0d | 2016-03-10 | 2016-03-10 |  |  |  | 232d | 82d | start no earlier than 2016-03-10 |
| 337 | 86 | CERN coil 107 completed | milestone | 0d | 2016-05-02 | 2016-05-02 |  |  |  | 195d | 45d | start no earlier than 2016-05-02 |
| 338 | 87 | MQXFD3 assembly @ CERN |  | 9w | 2016-04-11 A | 2016-06-13 |  | 22% | 7w | 165d | 15d | start no earlier than 2016-04-10 |
| 339 | 88 | **MQXFS3 Assembly @ CERN** |  | 55d | 2016-07-06 | 2016-09-21 | 335, 294, 338, 336, 337, 280 |  |  | 150d | 7d |  |
| 340 | 88.1 | Assembly & loading, QA |  | 7w | 2016-07-06 | 2016-08-23 |  |  |  | 150d | 0d |  |
| 341 | 88.2 | Splices, pizza-box & test prep |  | 20d | 2016-08-24 | 2016-09-21 | 340 |  |  | 150d |  |  |
| 342 | 89 | Test @ CERN |  | 45d | 2016-10-03 | 2016-12-06 | 339, 283 |  |  | 143d | 0d |  |
| 343 | 90 | MQXFS3 Test Analysis |  | 4w | 2016-12-07 | 2017-01-05 | 342 |  |  | 145d | 0d |  |
| 344 | 91 | MQXFS3 Test Review | milestone | 0d | 2017-01-05 | 2017-01-05 | 343 |  |  | 145d | 89d |  |
| 345 | 92 | **MQXFS3 disassembly** |  | 20d | 2016-12-07 | 2017-01-05 | 342 |  |  | 605d |  |  |
| 346 | 92.1 | Disassembly pizza-box |  | 5d | 2016-12-07 | 2016-12-13 |  |  |  | 605d | 0d |  |
| 347 | 92.2 | disassembly |  | 15d | 2016-12-14 | 2017-01-05 | 346 |  |  | 605d |  |  |
| 348 | 93 | CERN coil 108 completed | milestone | 0d | 2016-12-05 | 2016-12-05 |  |  |  | 262d | 217d | start no earlier than 2016-12-05 |
| 349 | 94 | CERN coil 109 completed | milestone | 0d | 2017-01-17 | 2017-01-17 |  |  |  | 234d | 189d | start no earlier than 2017-01-17 |
| 350 | 95 | Prep structure w thin laminations |  | 8w | 2017-03-17 | 2017-05-11 | 462, 268 |  |  | 56d | 0d | start no earlier than 2017-01-01 |
| 351 | 96 | **MQXFS4 Assembly @ LARP** |  | 70d | 2017-10-12 | 2018-01-25 | 309, 316, 348, 350, 349 |  |  | 45d | 0d |  |
| 352 | 96.1 | Assembly & loading |  | 9w | 2017-10-12 | 2017-12-15 |  |  |  | 45d | 0d |  |
| 353 | 96.2 | shipment preparation |  | 10d | 2017-12-18 | 2018-01-02 | 352 |  |  | 45d | 0d |  |
| 354 | 96.3 | shipment |  | 1w | 2018-01-04 | 2018-01-10 | 353 |  |  | 45d | 0d |  |
| 355 | 96.4 | Test prep |  | 10d | 2018-01-11 | 2018-01-25 | 354 |  |  | 45d |  |  |
| 356 | 97 | Test |  | 45d | 2018-01-26 | 2018-03-29 | 351 |  |  | 45d | 0d |  |
| 357 | 98 | MQXFS4 Test Analysis |  | 4w | 2018-03-30 | 2018-04-26 | 356 |  |  | 45d | 0d |  |
| 358 | 99 | MQXFS4 Test Review | milestone | 0d | 2018-04-26 | 2018-04-26 | 357 |  |  | 45d | 0d |  |

| ID | WBS | Task | Type | Duration | Start | Finish | Predecessors | Complete | Total slack | Free slack | Constraint | Resources | Work | Actual work | Cost | Actual cost |
| --- | --- | --- | --- | --- | --- | --- | --- | --- | --- | --- | --- | --- | --- | --- | --- | --- |
| 359 | 100 | **MQXFS4 disassembly** |  | 30d | 2018-01-26 | 2018-03-08 | 351 |  | 175d | 31d |  |  |  |  |  |  |
| 360 | 100.1 | shipment to LBNL |  | 10d | 2018-01-26 | 2018-02-08 |  |  | 175d | 0d |  |  |  |  |  |  |
| 361 | 100.2 | Disassembly pizza-box |  | 5d | 2018-02-09 | 2018-02-15 | 360 |  | 175d | 0d |  |  |  |  |  |  |
| 362 | 100.3 | Disassembly |  | 15d | 2018-02-16 | 2018-03-08 | 361 |  | 175d |  |  |  |  |  |  |  |
| 363 | 101 | **MQXFS4b Assembly @ LARP** |  | 70d | 2018-04-23 | 2018-07-30 | 359, 322, 329 |  | 144d | 0d |  |  |  |  |  |  |
| 364 | 101.1 | Assembly & loading |  | 9w | 2018-04-23 | 2018-06-22 |  |  | 144d | 0d |  |  |  |  |  |  |
| 365 | 101.2 | shipment preparation |  | 10d | 2018-06-25 | 2018-07-09 | 364 |  | 144d | 0d |  |  |  |  |  |  |
| 366 | 101.3 | shipment |  | 1w | 2018-07-10 | 2018-07-16 | 365 |  | 144d | 0d |  |  |  |  |  |  |
| 367 | 101.4 | Test prep |  | 10d | 2018-07-17 | 2018-07-30 | 366 |  | 144d |  |  |  |  |  |  |  |
| 368 | 102 | Test |  | 45d | 2018-07-31 | 2018-10-02 | 363 |  | 144d | 0d |  |  |  |  |  |  |
| 369 | 103 | MQXFS4b Test Analysis |  | 4w | 2018-10-03 | 2018-10-30 | 368 |  | 144d | 0d |  |  |  |  |  |  |
| 370 | 104 | MQXFS4b Test Review | milestone | 0d | 2018-10-30 | 2018-10-30 | 369 |  | 144d |  |  |  |  |  |  |  |
| 371 | 105 | **LHQ mirror parts & Mech Model** |  | 20d | 2014-02-03 A | 2014-02-28 A |  | 100% |  |  |  |  | 240h | 240h | 28,964.8 | 28,964.8 |
| 372 | 105.1 | Complete procurement | milestone | 0d | 2014-02-03 A | 2014-02-03 A |  | 100% |  |  | start no earlier than 2014-02-03 |  |  |  |  |  |
| 373 | 105.2 | Inspection and QC |  | 10d | 2014-02-03 A | 2014-02-14 A | 372 | 100% |  |  |  | QC - F; Engineer (Sr) - F [50%] | 120h | 120h | 15,464.8 | 15,464.8 |
| 374 | 105.3 | Mechanical Model |  | 10d | 2014-02-17 A | 2014-02-28 A | 373 | 100% |  |  |  | Engineer (Sr) - F [50%]; Technician - F | 120h | 120h | 13,500 | 13,500 |
| 375 | 106 | **LHQ coil #3** |  | 113d | 2013-10-14 A | 2014-03-25 A |  | 100% |  |  |  |  |  |  |  |  |
| 376 | 106.1 | Coil Wind / Cure |  | 21d | 2013-10-14 A | 2013-11-11 A |  | 100% |  |  | start no earlier than 2013-10-14 |  |  |  |  |  |
| 377 | 106.2 | Coil shipment |  | 12d | 2013-11-12 A | 2013-11-27 A | 376 | 100% |  |  |  |  |  |  |  |  |
| 378 | 106.3 | Coil React |  | 23d | 2013-11-28 A | 2014-01-02 A | 377 | 100% |  |  |  |  |  |  |  |  |
| 379 | 106.4 | Coil Impreg |  | 35d | 2014-01-03 A | 2014-02-21 A | 378 | 100% |  |  |  |  |  |  |  |  |
| 380 | 106.5 | Coil shipment |  | 12d | 2014-02-24 A | 2014-03-11 A | 379 | 100% |  |  |  |  |  |  |  |  |
| 381 | 106.6 | Coil instrumentation |  | 10d | 2014-03-12 A | 2014-03-25 A | 380 | 100% |  |  |  |  |  |  |  |  |
| 382 | 107 | LHQ Mirror Readiness Rev. | milestone | 0d | 2014-03-25 A | 2014-03-25 A | 375, 371 | 100% |  |  |  |  |  |  |  |  |

| ID | WBS | Task | Type | Duration | Start | Finish | Predecessors | Complete | Constraint | Resources | Work | Actual work | Cost | Actual cost |
| --- | --- | --- | --- | --- | --- | --- | --- | --- | --- | --- | --- | --- | --- | --- |
| 383 | 108 | **LHQM1 mirror** |  | 147d | 2014-03-26 A | 2014-10-21 A | 382 | 100% |  |  | 2442.4h | 2442.4h | 252,502.8 | 252,502.8 |
| 384 | 108.1 | LHQM01 mirror assembly |  | 9w | 2014-03-26 A | 2014-05-28 A |  | 100% |  | Engineer (Sr) - F [33%]; Technician - F [200%] | 838.8h | 838.8h | 77,461.71 | 77,461.71 |
| 385 | 108.2 | LHQM01 in the press |  | 10w | 2014-06-23 A | 2014-09-02 A | 384 | 100% | start no earlier than 2014-06-23 | Engineer (Sr) - F [75%]; Technician - F [200%] | 1100h | 1100h | 116,742 | 116,742 |
| 386 | 108.3 | LHQM01 final prep |  | 3w | 2014-09-03 A | 2014-09-23 A | 385 | 100% |  | Engineer (Sr) - F [33%]; Technician - F [200%] | 279.6h | 279.6h | 25,820.57 | 25,820.57 |
| 387 | 108.4 | LQHM01 test |  | 1mo | 2014-09-24 A | 2014-10-21 A | 386 | 100% |  | Technician - F [50%]; Engineer (Sr) - F [70%]; Scientist - F [20%] | 224h | 224h | 32,478.53 | 32,478.53 |
| 388 | 109 | **LHQ feedback to MQXFL** |  | 10d | 2014-10-22 A | 2014-11-04 A | 383 | 100% |  |  |  |  |  |  |
| 389 | 109.1 | LHQM1 test analysis |  | 10d | 2014-10-22 A | 2014-11-04 A |  | 100% |  |  |  |  |  |  |
| 390 | 110 | LHQ program end | milestone | 0d | 2014-11-18 A | 2014-11-18 A | 388 | 100% |  |  |  |  |  |  |
| 391 | 111 | **Long Winder set up @ FNAL** |  | 101d | 2014-10-01 A | 2015-02-27 A |  | 100% |  |  |  |  |  |  |
| 392 | 111.1 | Selva Winder phase 0 completed | milestone | 0d | 2014-10-01 A | 2014-10-01 A |  | 100% | start no earlier than 2014-10-01 |  |  |  |  |  |
| 393 | 111.2 | Selva winder tests |  | 20d | 2014-10-01 A | 2014-10-28 A | 392, 92 | 100% |  |  |  |  |  |  |
| 394 | 111.3 | Selva winder commissioned | milestone | 0d | 2015-02-02 A | 2015-02-02 A | 393 | 100% | start no earlier than 2015-02-02 |  |  |  |  |  |
| 395 | 111.4 | winding tests |  | 20d | 2015-02-02 A | 2015-02-27 A | 394 | 100% |  |  |  |  |  |  |
| 396 | 112 | **QXFP #1 for Mirror** |  | 194d | 2015-05-04 A | 2016-02-11 A | 14, 44, 141, 388, 395 | 100% |  |  |  |  |  |  |
| 397 | 112.1 | Coil Wind / Cure |  | 44d | 2015-05-04 A | 2015-07-06 A |  | 100% | start no earlier than 2015-05-04 |  |  |  |  |  |
| 398 | 112.2 | Reaction fixture dry assembly |  | 10d | 2015-07-07 A | 2015-07-20 A | 397 | 100% |  |  |  |  |  |  |
| 399 | 112.3 | Prep for shipment in Ract fixture |  | 12d | 2015-07-21 A | 2015-08-05 A | 398 | 100% |  |  |  |  |  |  |
| 400 | 112.4 | shipment |  | 15d | 2015-08-06 A | 2015-08-26 A | 399 | 100% |  |  |  |  |  |  |
| 401 | 112.5 | Coil React |  | 33d | 2015-08-27 A | 2015-10-13 A | 400 | 100% |  |  |  |  |  |  |
| 402 | 112.6 | Coil Impreg |  | 45d | 2015-10-14 A | 2016-01-15 A | 401 | 100% |  |  |  |  |  |  |
| 403 | 112.7 | Coil shipment |  | 18d | 2016-01-19 A | 2016-02-11 A | 402 | 100% |  |  |  |  |  |  |
| 404 | 113 | Techs training & Selva improv. |  | 15d | 2015-07-13 A | 2015-07-31 A | 397 | 100% | start no earlier than 2015-07-12 |  |  |  |  |  |
| 405 | 114 | **QXFP #1b Practice Coil** |  | 112d | 2015-08-03 A | 2016-01-14 A | 404 | 100% |  |  |  |  |  |  |
| 406 | 114.1 | Coil Wind / Cure |  | 32d | 2015-08-03 A | 2015-09-16 A | 397 | 100% | finish no earlier than 2015-08-31 |  |  |  |  |  |
| 407 | 114.2 | Complete FNAL fixtures |  | 1w | 2015-09-17 A | 2015-09-23 A | 406 | 100% |  |  |  |  |  |  |
| 408 | 114.3 | Coil React |  | 30d | 2015-09-24 A | 2015-11-04 A | 407 | 100% |  |  |  |  |  |  |
| 409 | 114.4 | Coil Impreg |  | 30d | 2015-11-05 A | 2015-12-18 A | 408 | 100% |  |  |  |  |  |  |
| 410 | 114.5 | Coil inspection |  | 15d | 2015-12-21 A | 2016-01-14 A | 409 | 100% |  |  |  |  |  |  |

| ID | WBS | Task | Type | Duration | Start | Finish | Predecessors | Complete | Remaining | Total slack | Free slack | Constraint |
| --- | --- | --- | --- | --- | --- | --- | --- | --- | --- | --- | --- | --- |
| 411 | 115 | **QXFP #2 (last 1st gen coil)** |  | 142d | 2015-10-14 A | 2016-05-09 | 142 | 89% | 16.23d | 171d | 115d |  |
| 412 | 115.1 | Coil Wind / Cure |  | 25d | 2015-10-14 A | 2015-11-17 A | 401, 406 | 100% |  |  |  |  |
| 413 | 115.2 | shipment |  | 15d | 2015-11-18 A | 2015-12-10 A | 412 | 100% |  |  |  |  |
| 414 | 115.3 | Coil React |  | 33d | 2015-12-11 A | 2016-02-02 A | 402FS-20d, 413 | 100% |  |  |  |  |
| 415 | 115.4 | Coil Impreg |  | 45d | 2016-02-03 A | 2016-04-07 A | 414 | 100% |  |  |  |  |
| 416 | 115.5 | shipment to LBNL |  | 12d | 2016-04-08 A | 2016-04-25 | 415 | 50% | 6d | 171d | 0d |  |
| 417 | 115.6 | Coil instrumentation |  | 10d | 2016-04-26 | 2016-05-09 | 416 |  |  | 171d |  |  |
| 418 | 116 | Press tested & ready for mirror | milestone | 0d | 2015-12-15 A | 2015-12-15 A |  | 100% |  |  |  | start no earlier than 2015-12-15 |
| 419 | 117 | Shipping crate delivered | milestone | 0d | 2016-05-09 | 2016-05-09 |  |  |  | 772d |  | start no earlier than 2016-05-09 |
| 420 | 118 | **MQXFP Mirror assembly** |  | 84d | 2016-02-12 A | 2016-06-09 A | 194, 418, 396 | 100% |  |  |  |  |
| 421 | 118.1 | Coil CCM and prep |  | 2w | 2016-02-12 A | 2016-02-25 A |  | 100% |  |  |  |  |
| 422 | 118.2 | Assembly |  | 5w | 2016-02-26 A | 2016-03-31 A | 421 | 100% |  |  |  |  |
| 423 | 118.3 | In the welding press |  | 22d | 2016-04-01 A | 2016-05-02 A | 422 | 100% |  |  |  |  |
| 424 | 118.4 | final prep |  | 27d | 2016-05-03 A | 2016-06-09 A | 423 | 100% |  |  |  |  |
| 425 | 119 | Shipment to BNL |  | 2w | 2016-06-10 A | 2016-06-23 A | 419, 420 | 100% |  |  |  |  |
| 426 | 120 | BNL Test facility commisioned | milestone | 0d | 2016-07-29 | 2016-07-29 |  |  |  | -8d | 0d | start no earlier than 2016-07-29 |
| 427 | 121 | Test prep |  | 2w | 2016-07-29 | 2016-08-11 | 426, 425 |  |  | -8d | 0d |  |
| 428 | 122 | Mirror test |  | 6w | 2016-08-12 | 2016-09-23 | 427 |  |  | -8d | 0d |  |
| 429 | 123 | MQXFL Mirror Test Analysis |  | 4w | 2016-09-26 | 2016-10-21 | 428 |  |  | 75d | 0d |  |
| 430 | 124 | MQXFL Mirror Test Review | milestone | 0d | 2016-10-21 | 2016-10-21 | 429 |  |  | 75d | 0d |  |
| 431 | 125 | **QXFP #3** |  | 110d | 2016-01-25 A | 2016-06-27 | 143, 288, 243FS-20d, 184 | 64% | 39.5d | 137d | 81d |  |
| 432 | 125.1 | Coil Wind / Cure |  | 30d | 2016-01-25 A | 2016-03-04 A | 412 | 100% |  |  |  | start no earlier than 2016-01-25 |
| 433 | 125.2 | Coil React |  | 23d | 2016-03-07 A | 2016-04-06 A | 409FS-10d, 432 | 100% |  |  |  |  |
| 434 | 125.3 | Coil Impreg |  | 35d | 2016-04-07 A | 2016-05-25 | 433 | 50% | 17.5d | 89d | 0d |  |
| 435 | 125.4 | Coil shipment |  | 12d | 2016-05-27 | 2016-06-13 | 434 |  |  | 137d | 0d |  |
| 436 | 125.5 | Coil instrumentation |  | 10d | 2016-06-14 | 2016-06-27 | 435 |  |  | 137d |  |  |

| ID | WBS | Task | Type | Duration | Start | Finish | Predecessors | Complete | Remaining | Total slack | Free slack | Constraint |
| --- | --- | --- | --- | --- | --- | --- | --- | --- | --- | --- | --- | --- |
| 437 | 126 | **QXFP #4** |  | 127d | 2016-03-07 A | 2016-09-01 | 144 | 53% | 59.34d | 90d | 34d |  |
| 438 | 126.1 | Coil Wind / Cure |  | 30d | 2016-03-07 A | 2016-04-15 A | 432 | 100% |  |  |  | start no earlier than 2015-10-01 |
| 439 | 126.2 | Coil Shipment |  | 12d | 2016-04-18 A | 2016-05-03 A | 438 | 100% |  |  |  |  |
| 440 | 126.3 | Coil React |  | 23d | 2016-05-04 A | 2016-06-06 A | 415FS-10d, 439 | 100% |  |  |  |  |
| 441 | 126.4 | Coil Impreg |  | 35d | 2016-06-07 | 2016-08-02 | 440 |  |  | 90d | 0d |  |
| 442 | 126.5 | Coil shipment |  | 12d | 2016-08-03 | 2016-08-18 | 441 |  |  | 90d | 0d |  |
| 443 | 126.6 | Coil instrumentation |  | 10d | 2016-08-19 | 2016-09-01 | 442 |  |  | 90d |  |  |
| 444 | 127 | **QXFP #5** |  | 110d | 2016-05-04 A | 2016-10-07 | 145 | 27% | 80d | 65d | 9d |  |
| 445 | 127.1 | Coil Wind / Cure |  | 30d | 2016-05-04 A | 2016-06-15 A | 438 | 100% |  |  |  | start no earlier than 2016-05-04 |
| 446 | 127.2 | Coil React |  | 23d | 2016-06-16 | 2016-07-19 | 434FS-10d, 445 |  |  | 65d | 0d |  |
| 447 | 127.3 | Coil Impreg |  | 35d | 2016-07-20 | 2016-09-07 | 446 |  |  | 65d | 0d |  |
| 448 | 127.4 | Coil shipment |  | 12d | 2016-09-08 | 2016-09-23 | 447 |  |  | 65d | 0d |  |
| 449 | 127.5 | Coil instrumentation |  | 10d | 2016-09-26 | 2016-10-07 | 448 |  |  | 65d |  |  |
| 450 | 128 | **QXFP #6** |  | 110d | 2016-08-26 | 2017-02-03 | 146, 428SS+10d |  |  | 585d |  |  |
| 451 | 128.1 | Coil Wind / Cure |  | 30d | 2016-08-26 | 2016-10-07 | 445, 434 |  |  | 585d | 0d | start no earlier than 2016-06-20 |
| 452 | 128.2 | Coil React |  | 23d | 2016-10-10 | 2016-11-09 | 451, 447FS-10d |  |  | 585d | 0d |  |
| 453 | 128.3 | Coil Impreg |  | 35d | 2016-11-10 | 2017-01-02 | 452 |  |  | 585d | 0d |  |
| 454 | 128.4 | Coil shipment |  | 12d | 2017-01-03 | 2017-01-20 | 453 |  |  | 585d | 0d |  |
| 455 | 128.5 | Coil instrumentation |  | 10d | 2017-01-23 | 2017-02-03 | 454 |  |  | 585d |  |  |
| 456 | 129 | MQXFA1 assembly Ready Rev | milestone | 0d | 2016-10-20 | 2016-10-20 | 411, 431, 444, 437, 114, 251, 430FS-20d |  |  | 56d | 0d | start no earlier than 2016-10-01 |
| 457 | 130 | **MQXFA1 assembly** |  | 100d | 2016-10-21 | 2017-03-16 | 456 |  |  | 56d | 0d |  |
| 458 | 130.1 | Coil pack assembly & insertion |  | 7w | 2016-10-21 | 2016-12-12 |  |  |  | 56d | 0d |  |
| 459 | 130.2 | Loading |  | 5w | 2016-12-13 | 2017-01-19 | 458 |  |  | 56d | 0d |  |
| 460 | 130.3 | Splice box & instrumentation |  | 3w | 2017-01-20 | 2017-02-09 | 459 |  |  | 56d | 0d |  |
| 461 | 130.4 | QA & shipment prep |  | 15d | 2017-02-10 | 2017-03-02 | 460 |  |  | 56d | 0d |  |
| 462 | 130.5 | shipment |  | 10d | 2017-03-03 | 2017-03-16 | 461 |  |  | 56d | 0d |  |
| 463 | 131 | test prep |  | 10d | 2017-03-17 | 2017-03-30 | 457 |  |  | 71d | 0d |  |
| 464 | 132 | Test |  | 60d | 2017-03-31 | 2017-06-23 | 463 |  |  | 71d | 0d |  |
| 465 | 133 | MQXFA1 Test Analysis |  | 4w | 2017-06-26 | 2017-07-24 | 464 |  |  | 95d | 0d |  |
| 466 | 134 | MQXFA1b preload increase |  | 30d | 2017-06-26 | 2017-08-07 | 464 |  |  | 71d | 0d |  |
| 467 | 135 | MQXFA1b Test w higher preload |  | 40d | 2017-08-08 | 2017-10-03 | 466 |  |  | 71d | 0d |  |
| 468 | 136 | MQXFA1b Test Analysis |  | 4w | 2017-10-04 | 2017-10-31 | 467 |  |  | 71d | 0d |  |
| 469 | 137 | MQXFA1b Test Review | milestone | 0d | 2017-10-31 | 2017-10-31 | 465, 468 |  |  | 71d | 0d |  |

| ID | WBS | Task | Type | Duration | Start | Finish | Predecessors | Total slack | Free slack | Constraint |
| --- | --- | --- | --- | --- | --- | --- | --- | --- | --- | --- |
| 470 | 138 | **MQXFA1b disassembly** |  | 40d | 2017-11-01 | 2018-01-01 | 469 | 71d | 15d |  |
| 471 | 138.1 | shipment prep |  | 5d | 2017-11-01 | 2017-11-07 |  | 71d | 0d |  |
| 472 | 138.2 | shipment |  | 10d | 2017-11-08 | 2017-11-21 | 471 | 71d | 0d |  |
| 473 | 138.3 | pizza box disassembly |  | 5d | 2017-11-22 | 2017-11-30 | 472 | 71d | 0d |  |
| 474 | 138.4 | magnet disassembly |  | 20d | 2017-12-01 | 2018-01-01 | 473 | 71d |  |  |
| 475 | 139 | **MQXFA1 disassembly** |  | 40d | 2017-06-26 | 2017-08-21 | 464 | 271d | 0d |  |
| 476 | 139.1 | shipment prep |  | 5d | 2017-06-26 | 2017-06-30 |  | 271d | 0d |  |
| 477 | 139.2 | shipment |  | 10d | 2017-07-03 | 2017-07-17 | 476 | 271d | 0d |  |
| 478 | 139.3 | pizza box disassembly |  | 5d | 2017-07-18 | 2017-07-24 | 477 | 271d | 0d |  |
| 479 | 139.4 | magnet disassembly |  | 20d | 2017-07-25 | 2017-08-21 | 478 | 271d |  |  |
| 480 | 140 | **MQXFA1b assembly** |  | 85d | 2017-08-22 | 2017-12-21 | 475 | 271d |  |  |
| 481 | 140.1 | Assembly & loading |  | 60d | 2017-08-22 | 2017-11-14 |  | 271d | 0d |  |
| 482 | 140.2 | QA & shipment prep |  | 15d | 2017-11-15 | 2017-12-07 | 481 | 271d | 0d |  |
| 483 | 140.3 | shipment |  | 10d | 2017-12-08 | 2017-12-21 | 482 | 271d | 0d |  |
| 484 | 141 | **MQXFA1b test w new coil(s)** |  | 70d | 2017-12-22 | 2018-04-04 |  | 271d |  |  |
| 485 | 141.1 | test prep |  | 10d | 2017-12-22 | 2018-01-09 | 483 | 271d | 0d |  |
| 486 | 141.2 | Test |  | 40d | 2018-01-10 | 2018-03-07 | 485 | 271d | 0d |  |
| 487 | 141.3 | Test analysis |  | 4w | 2018-03-08 | 2018-04-04 | 486 | 291d | 0d |  |
| 488 | 141.4 | Review | milestone | 0d | 2018-04-04 | 2018-04-04 | 487 | 291d |  |  |
| 489 | 142 | **MQXFA1b disassembly** |  | 40d | 2018-03-08 | 2018-05-02 | 486 | 271d |  |  |
| 490 | 142.1 | shipment prep |  | 5d | 2018-03-08 | 2018-03-14 |  | 271d | 0d |  |
| 491 | 142.2 | shipment |  | 10d | 2018-03-15 | 2018-03-28 | 490 | 271d | 0d |  |
| 492 | 142.3 | pizza box disassembly |  | 5d | 2018-03-29 | 2018-04-04 | 491 | 271d | 0d |  |
| 493 | 142.4 | magnet disassembly |  | 20d | 2018-04-05 | 2018-05-02 | 492 | 271d |  |  |
| 494 | 143 | QXFA coil parts ready | milestone | 0d | 2016-07-05 | 2016-07-05 |  | 0d |  | start no earlier than 2016-07-05 |
| 495 | 144 | QXFA R&I plates & bars | milestone | 0d | 2016-09-12 | 2016-09-12 |  | 24d | 0d | start no earlier than 2016-09-12 |

Notes:
- 480: MQXFA1 test stops earlier if MQXFA1b is needed for Project start

| ID | WBS | Task | Duration | Start | Finish | Predecessors | Total slack | Free slack | Constraint |
| --- | --- | --- | --- | --- | --- | --- | --- | --- | --- |
| 496 | 145 | **QXFA #101 (1st 4.2 m coil)** | 128d | 2016-07-05 | 2017-01-05 | 147, 494 | 0d |  |  |
| 497 | 145.1 | Coil Wind / Cure | 30d | 2016-07-05 | 2016-08-15 | 445 | 0d |  | start no earlier than 2012-10-01 |
| 498 | 145.2 | Coil React | 23d | 2016-09-12 | 2016-10-12 | 497, 447, 495 | 106d | 0d |  |
| 499 | 145.3 | Coil Impreg | 35d | 2016-10-13 | 2016-12-02 | 498 | 106d | 0d |  |
| 500 | 145.4 | Coil shipment | 12d | 2016-12-05 | 2016-12-20 | 499 | 280d | 0d |  |
| 501 | 145.5 | Coil instrumentation | 10d | 2016-12-21 | 2017-01-05 | 500 | 280d |  |  |
| 502 | 146 | **QXFA #102** | 122d | 2016-08-16 | 2017-02-09 | 428SS+10d, 149FS+10d |  |  |  |
| 503 | 146.1 | Coil Wind / Cure | 30d | 2016-08-16 | 2016-09-27 | 497 | 0d |  |  |
| 504 | 146.2 | Coil shipment | 12d | 2016-09-28 | 2016-10-13 | 503 | 0d |  |  |
| 505 | 146.3 | Coil React | 23d | 2016-10-14 | 2016-11-15 | 504, 495 | 0d |  |  |
| 506 | 146.4 | Coil Impreg | 35d | 2016-11-16 | 2017-01-09 | 505 | 0d |  |  |
| 507 | 146.5 | Coil shipment | 12d | 2017-01-10 | 2017-01-26 | 506 | 0d |  |  |
| 508 | 146.6 | Coil instrumentation | 10d | 2017-01-27 | 2017-02-09 | 507 | 0d |  |  |
| 509 | 147 | **QXFA #103** | 110d | 2016-10-24 | 2017-03-31 | 430, 150FS+10d | 82d | 79d |  |
| 510 | 147.1 | Coil Wind / Cure | 30d | 2016-10-24 | 2016-12-06 | 503 | 82d | 0d |  |
| 511 | 147.2 | Coil React | 23d | 2016-12-07 | 2017-01-10 | 510, 499FS-10d | 94d | 0d |  |
| 512 | 147.3 | Coil Impreg | 35d | 2017-01-11 | 2017-03-01 | 511 | 94d | 0d |  |
| 513 | 147.4 | Coil shipment | 12d | 2017-03-02 | 2017-03-17 | 512 | 210d | 0d |  |
| 514 | 147.5 | Coil instrumentation | 10d | 2017-03-20 | 2017-03-31 | 513, 507 | 210d | 69d |  |
| 515 | 148 | **QXFA #104** | 122d | 2017-02-01 | 2017-07-24 | 151FS+10d | 45d | 0d |  |
| 516 | 148.1 | Coil Wind / Cure | 30d | 2017-02-01 | 2017-03-14 | 510 | 45d | 0d | start no earlier than 2016-10-01 |
| 517 | 148.2 | Coil shipment | 12d | 2017-03-15 | 2017-03-30 | 516 | 141d | 0d |  |
| 518 | 148.3 | Coil React | 23d | 2017-03-31 | 2017-05-02 | 517, 506FS-5d | 141d | 0d |  |
| 519 | 148.4 | Coil Impreg | 35d | 2017-05-03 | 2017-06-21 | 518 | 141d | 0d |  |
| 520 | 148.5 | Coil shipment | 12d | 2017-06-22 | 2017-07-10 | 519 | 141d | 0d |  |
| 521 | 148.6 | Coil instrumentation | 10d | 2017-07-11 | 2017-07-24 | 520, 514 | 141d | 8d |  |

| ID | WBS | Task | Type | Duration | Start | Finish | Predecessors | Total slack | Free slack |
| --- | --- | --- | --- | --- | --- | --- | --- | --- | --- |
| 522 | 149 | **QXFA #105** |  | 110d | 2017-03-15 | 2017-08-17 | 152FS+10d | 45d |  |
| 523 | 149.1 | Coil Wind / Cure |  | 30d | 2017-03-15 | 2017-04-25 | 516 | 45d | 0d |
| 524 | 149.2 | Coil React |  | 23d | 2017-04-26 | 2017-05-29 | 512FS-10d, 523 | 45d | 0d |
| 525 | 149.3 | Coil Impreg |  | 35d | 2017-05-30 | 2017-07-18 | 524 | 45d | 0d |
| 526 | 149.4 | Coil shipment |  | 12d | 2017-07-19 | 2017-08-03 | 525 | 448d | 0d |
| 527 | 149.5 | Coil instrumentation |  | 10d | 2017-08-04 | 2017-08-17 | 526, 521 | 448d |  |
| 528 | 150 | **MQXFA2 assembly** |  | 90d | 2017-07-25 | 2017-11-30 | 502, 509, 515, 464FS-40d, 557, 496 | 141d | 0d |
| 529 | 150.1 | Assembly & loading |  | 65d | 2017-07-25 | 2017-10-24 |  | 141d | 0d |
| 530 | 150.2 | QA & shipment prep |  | 15d | 2017-10-25 | 2017-11-14 | 529 | 141d | 0d |
| 531 | 150.3 | shipment |  | 10d | 2017-11-15 | 2017-11-30 | 530 | 141d |  |
| 532 | 151 | test prep |  | 10d | 2017-12-01 | 2017-12-14 | 528 | 141d | 0d |
| 533 | 152 | Test |  | 50d | 2017-12-15 | 2018-02-28 | 532 | 141d | 0d |
| 534 | 153 | MQXFA2 Test Analysis |  | 4w | 2018-03-01 | 2018-03-28 | 533 | 296d | 0d |
| 535 | 154 | MQXFA2 Test Review | milestone | 0d | 2018-03-28 | 2018-03-28 | 534 | 296d |  |
| 536 | 155 | **MQXFA2 disassembly** |  | 40d | 2018-01-18 | 2018-03-14 | 533FS-30d | 141d | 0d |
| 537 | 155.1 | shipment prep |  | 5d | 2018-01-18 | 2018-01-24 |  | 141d | 0d |
| 538 | 155.2 | shipment |  | 10d | 2018-01-25 | 2018-02-07 | 537 | 141d | 0d |
| 539 | 155.3 | pizza box disassembly |  | 5d | 2018-02-08 | 2018-02-14 | 538 | 141d | 0d |
| 540 | 155.4 | magnet disassembly |  | 20d | 2018-02-15 | 2018-03-14 | 539 | 141d |  |
| 541 | 156 | **QXFA #106** |  | 122d | 2017-06-23 | 2017-12-15 | 464FS-20d, 157FS+10d | 86d | 59d |
| 542 | 156.1 | Coil Wind / Cure |  | 30d | 2017-06-23 | 2017-08-04 | 523 | 86d | 0d |
| 543 | 156.2 | Coil shipment |  | 12d | 2017-08-07 | 2017-08-22 | 542 | 200d | 0d |
| 544 | 156.3 | Coil React |  | 23d | 2017-08-23 | 2017-09-25 | 543, 519 | 200d | 0d |
| 545 | 156.4 | Coil Impreg |  | 35d | 2017-09-26 | 2017-11-13 | 544 | 200d | 0d |
| 546 | 156.5 | Coil shipment |  | 12d | 2017-11-14 | 2017-12-01 | 545 | 200d | 0d |
| 547 | 156.6 | Coil instrumentation |  | 10d | 2017-12-04 | 2017-12-15 | 546 | 200d |  |

| ID | WBS | Task | Type | Duration | Start | Finish | Predecessors | Total slack | Free slack | Constraint |
| --- | --- | --- | --- | --- | --- | --- | --- | --- | --- | --- |
| 548 | 157 | **MQXFA2b** |  | 95d | 2018-03-15 | 2018-07-26 | 536, 541 | 141d | 0d |  |
| 549 | 157.1 | Assembly & loading |  | 60d | 2018-03-15 | 2018-06-06 |  | 141d | 0d |  |
| 550 | 157.2 | QA & shipment prep |  | 15d | 2018-06-07 | 2018-06-27 | 549 | 141d | 0d |  |
| 551 | 157.3 | shipment |  | 10d | 2018-06-28 | 2018-07-12 | 550 | 141d | 0d |  |
| 552 | 157.4 | test prep |  | 10d | 2018-07-13 | 2018-07-26 | 551 | 141d |  |  |
| 553 | 158 | Test |  | 50d | 2018-07-27 | 2018-10-05 | 548 | 141d | 0d |  |
| 554 | 159 | Test analysis |  | 4w | 2018-10-08 | 2018-11-02 | 553 | 141d | 0d |  |
| 555 | 160 | Review | milestone | 0d | 2018-11-02 | 2018-11-02 | 554 | 141d |  |  |
| 556 | 161 | MQXF TDR completed | milestone | 0d | 2016-09-30 | 2016-09-30 |  | 180d | 1d | start no earlier than 2016-09-30 |
| 557 | 162 | **MQXFA2 Magnet structure** |  | 235d | 2016-05-25 | 2017-04-28 | 246 | 200d | 59d |  |
| 558 | 162.1 | Design and drawings adjust. |  | 8w | 2016-05-25 | 2016-07-21 |  | 200d | 0d | start no earlier than 2016-05-25 |
| 559 | 162.2 | long lead items procurement |  | 27w | 2016-07-22 | 2017-02-03 | 558 | 200d | 0d |  |
| 560 | 162.3 | LLI inspection and instrum. |  | 6w | 2017-02-06 | 2017-03-17 | 559 | 200d | 0d |  |
| 561 | 162.4 | procurement |  | 20w | 2016-10-03 | 2017-02-24 | 558, 556 | 200d | 0d | start no earlier than 2016-10-02 |
| 562 | 162.5 | inspection & instrumentation |  | 11w | 2016-12-29 | 2017-03-17 | 561FS-8w | 200d | 0d |  |
| 563 | 162.6 | Yoke-shell sub-assembly |  | 6w | 2017-03-20 | 2017-04-28 | 562, 560 | 200d |  |  |
| 564 | 163 | **Wind&Cure line at BNL** |  | 235d | 2016-10-03 | 2017-09-06 |  | 0d |  |  |
| 565 | 163.1 | Setup & Commissioning |  | 235d | 2016-10-03 | 2017-09-06 |  | 0d |  | start no earlier than 2016-10-01 |
| 566 | 164 | Complete Wind&Cure equip. at BNL | milestone | 0d | 2017-09-06 | 2017-09-06 | 564 | 0d |  | start no earlier than 2017-09-05 |
| 567 | 165 | **W&C PCs at BNL (Long)** |  | 70d | 2017-09-07 | 2017-12-15 | 566, 154FS+10d | 0d |  |  |
| 568 | 165.1 | Long Coil Wind / Cure |  | 60d | 2017-09-07 | 2017-12-01 |  | 0d |  |  |
| 569 | 165.2 | Coil inspection |  | 10d | 2017-12-04 | 2017-12-15 | 568 | 0d |  |  |
| 570 | 166 | **QXFA #201 (1st full coil at BNL)** |  | 110d | 2017-12-18 | 2018-05-24 | 567, 155FS+10d | 0d |  |  |
| 571 | 166.1 | Coil Wind / Cure |  | 30d | 2017-12-18 | 2018-02-01 |  | 0d |  | start no earlier than 2016-10-03 |
| 572 | 166.2 | Coil React |  | 23d | 2018-02-02 | 2018-03-06 | 571 | 0d |  |  |
| 573 | 166.3 | Coil Impreg |  | 35d | 2018-03-07 | 2018-04-24 | 572 | 0d |  |  |
| 574 | 166.4 | Coil shipment |  | 12d | 2018-04-25 | 2018-05-10 | 573 | 0d |  |  |
| 575 | 166.5 | Coil instrumentation |  | 10d | 2018-05-11 | 2018-05-24 | 574 | 0d |  |  |

| ID | WBS | Task | Type | Duration | Start | Finish | Predecessors | Total slack | Free slack | Constraint |
| --- | --- | --- | --- | --- | --- | --- | --- | --- | --- | --- |
| 576 | 167 | **MQXFA Mirror#2 (optional)** |  | 130d | 2018-05-25 | 2018-11-28 | 570 | 125d |  |  |
| 577 | 167.1 | Assembly & loading |  | 45d | 2018-05-25 | 2018-07-27 |  | 125d | 0d |  |
| 578 | 167.2 | QA & shipment prep |  | 15d | 2018-07-30 | 2018-08-17 | 577 | 125d | 0d |  |
| 579 | 167.3 | shipment |  | 10d | 2018-08-20 | 2018-08-31 | 578 | 125d | 0d |  |
| 580 | 167.4 | test prep |  | 10d | 2018-09-04 | 2018-09-17 | 579 | 125d | 0d |  |
| 581 | 167.5 | Test |  | 50d | 2018-09-18 | 2018-11-28 | 580 | 125d |  |  |
| 582 | 168 | Completed coil modifications based on MQXF TDR | milestone | 0d | 2017-03-31 | 2017-03-31 | 556FS+24w | 175d | 80d | start no earlier than 2017-03-31 |
| 583 | 169 | MQXFA3 Readiness Review | milestone | 0d | 2017-07-24 | 2017-07-24 | 582, 344, 465 | 95d | 9d |  |
| 584 | 170 | **QXFA #202** |  | 110d | 2018-04-27 | 2018-10-01 | 583, 570FS-20d, 159FS+10d | 0d |  |  |
| 585 | 170.1 | Coil Wind / Cure |  | 30d | 2018-04-27 | 2018-06-07 | 571 | 0d |  | start no earlier than 2017-03-05 |
| 586 | 170.2 | Coil React |  | 23d | 2018-06-08 | 2018-07-11 | 585, 573FS-10d | 0d |  |  |
| 587 | 170.3 | Coil Impreg |  | 35d | 2018-07-12 | 2018-08-29 | 586 | 0d |  |  |
| 588 | 170.4 | Coil shipment |  | 12d | 2018-08-30 | 2018-09-17 | 587 | 0d |  |  |
| 589 | 170.5 | Coil instrumentation |  | 10d | 2018-09-18 | 2018-10-01 | 588 | 0d |  |  |
| 590 | 171 | **QXFA #203** |  | 110d | 2018-09-11 | 2019-02-19 | 584FS-15d | 70d |  |  |
| 591 | 171.1 | Coil Wind / Cure |  | 30d | 2018-09-11 | 2018-10-22 | 585 | 70d | 0d | start no earlier than 2017-05-07 |
| 592 | 171.2 | Coil React |  | 23d | 2018-10-23 | 2018-11-26 | 591, 587FS-10d | 70d | 0d |  |
| 593 | 171.3 | Coil Impreg |  | 35d | 2018-11-27 | 2019-01-17 | 592 | 70d | 0d |  |
| 594 | 171.4 | Coil shipment |  | 12d | 2019-01-18 | 2019-02-05 | 593 | 70d | 0d |  |
| 595 | 171.5 | Coil instrumentation |  | 10d | 2019-02-06 | 2019-02-19 | 594 | 70d |  |  |
| 596 | 172 | **QXFA #107** |  | 110d | 2017-08-07 | 2018-01-16 | 583, 158FS+10d | 86d |  |  |
| 597 | 172.1 | Coil Wind / Cure |  | 30d | 2017-08-07 | 2017-09-18 | 542 | 86d | 0d |  |
| 598 | 172.2 | Coil React |  | 23d | 2017-09-19 | 2017-10-19 | 597 | 86d | 0d |  |
| 599 | 172.3 | Coil Impreg |  | 35d | 2017-10-20 | 2017-12-11 | 598 | 86d | 0d |  |
| 600 | 172.4 | Coil shipment |  | 12d | 2017-12-12 | 2017-12-29 | 599 | 182d | 0d |  |
| 601 | 172.5 | Coil instrumentation |  | 10d | 2018-01-01 | 2018-01-16 | 600 | 182d |  |  |

| ID | WBS | Task | Type | Duration | Start | Finish | Predecessors | Total slack | Free slack | Constraint |
| --- | --- | --- | --- | --- | --- | --- | --- | --- | --- | --- |
| 602 | 173 | **QXFA #108** |  | 112d | 2017-10-11 | 2018-03-23 | 160FS+10d | 88d |  |  |
| 603 | 173.1 | Coil Wind / Cure |  | 30d | 2017-10-11 | 2017-11-21 | 597 | 88d | 2d | start no earlier than 2017-10-02 |
| 604 | 173.2 | Coil React |  | 23d | 2017-11-28 | 2018-01-01 | 603, 599FS-10d | 86d | 0d |  |
| 605 | 173.3 | Coil Impreg |  | 35d | 2018-01-02 | 2018-02-21 | 604 | 86d | 0d |  |
| 606 | 173.4 | Coil shipment |  | 12d | 2018-02-22 | 2018-03-09 | 605 | 134d | 0d |  |
| 607 | 173.5 | Coil instrumentation |  | 10d | 2018-03-12 | 2018-03-23 | 606 | 134d |  |  |
| 608 | 174 | **QXFA #109** |  | 111d | 2017-12-21 | 2018-05-30 | 161FS+10d | 86d |  |  |
| 609 | 174.1 | Coil Wind / Cure |  | 30d | 2017-12-21 | 2018-02-06 | 603 | 87d | 1d |  |
| 610 | 174.2 | Coil React |  | 23d | 2018-02-08 | 2018-03-12 | 609, 605FS-10d | 86d | 0d |  |
| 611 | 174.3 | Coil Impreg |  | 35d | 2018-03-13 | 2018-04-30 | 610 | 86d | 0d |  |
| 612 | 174.4 | Coil shipment |  | 12d | 2018-05-01 | 2018-05-16 | 611 | 86d | 0d |  |
| 613 | 174.5 | Coil instrumentation |  | 10d | 2018-05-17 | 2018-05-30 | 612 | 86d |  |  |
| 614 | 175 | **MQXFA3 Structure Adjust for V.E.** |  | 306d | 2017-05-12 | 2018-07-27 | 344, 350 | 45d |  |  |
| 615 | 175.1 | Design and drawings adjust. |  | 8w | 2017-05-12 | 2017-07-10 |  | 56d | 0d |  |
| 616 | 175.2 | thin-lamination parts procurement |  | 27w | 2017-07-11 | 2018-01-24 | 615 | 56d | 0d |  |
| 617 | 175.3 | inspection & instrumentation |  | 11w | 2018-01-25 | 2018-04-11 | 616, 470 | 56d | 11d |  |
| 618 | 175.4 | Yoke-shell sub-assembly |  | 6w | 2018-04-27 | 2018-06-07 | 617, 358 | 45d | 0d |  |
| 619 | 175.5 | Mechanical test with dummy coils |  | 5w | 2018-06-08 | 2018-07-13 | 618 | 45d | 0d |  |
| 620 | 175.6 | disassembly dummy coils |  | 2w | 2018-07-16 | 2018-07-27 | 619 | 45d |  |  |
| 621 | 176 | **MQXFA3 assembly** |  | 95d | 2018-10-02 | 2019-02-19 | 584, 596, 358, 614, 602, 608 | 0d |  |  |
| 622 | 176.1 | Assembly & loading |  | 60d | 2018-10-02 | 2018-12-28 |  | 0d |  |  |
| 623 | 176.2 | QA & shipment prep |  | 15d | 2018-12-31 | 2019-01-22 | 622 | 0d |  |  |
| 624 | 176.3 | shipment |  | 10d | 2019-01-23 | 2019-02-05 | 623 | 0d |  |  |
| 625 | 176.4 | test prep |  | 10d | 2019-02-06 | 2019-02-19 | 624 | 0d |  |  |
| 626 | 177 | Test |  | 50d | 2019-02-20 | 2019-04-30 | 621 | 0d |  |  |
| 627 | 178 | MQXFA3 Test Analysis |  | 4w | 2019-05-01 | 2019-05-28 | 626 | 0d |  |  |
| 628 | 179 | MQXFA3 Test Review | milestone | 0d | 2019-05-28 | 2019-05-28 | 627 | 0d |  |  |

| ID | WBS | Task | Duration | Start | Finish | Total slack | Constraint |
| --- | --- | --- | --- | --- | --- | --- | --- |
| 629 | 180 | **Cold mass development** | 500d | 2016-10-03 | 2018-09-24 | 170d |  |
| 630 | 180.1 | Cold mass D&D | 500d | 2016-10-03 | 2018-09-24 | 170d | start no earlier than 2016-10-01 |
| 631 | 181 | **Horizontal test facility upgr** | 500d | 2016-10-03 | 2018-09-24 | 170d |  |
| 632 | 181.1 | Mech, Cryo, Power, DAQ | 500d | 2016-10-03 | 2018-09-24 | 170d | start no earlier than 2016-10-01 |
| 633 | 182 | **Reusable cryostat for CM tests** | 500d | 2016-10-03 | 2018-09-24 | 170d |  |
| 634 | 182.1 | Design, Proc, Assembly, Commis | 500d | 2016-10-03 | 2018-09-24 | 170d | start no earlier than 2016-10-01 |
